# ALTESA

Schedule from Primavera P6, 2024-06-13 to 2025-11-12, data date 2024-06-13.

## Calendars

- FYA DC: Mon-Sun 07:00-17:00.

## Schedule

| ID | WBS | Activity | Type | Duration | Start | Finish | Predecessors | Total float | Free float | Constraint | MSP Outline Number | MSP Unique ID | MSP Project Name | Imported Early Start | Imported Late Start | Imported Start | Imported Early Finish | Imported Late Finish | Imported Finish | MSP ID | MSP Task Order |
| --- | --- | --- | --- | --- | --- | --- | --- | --- | --- | --- | --- | --- | --- | --- | --- | --- | --- | --- | --- | --- | --- |
|  | 000001 | **Hitos** |  |  | 2024-06-13 | 2025-11-12 |  |  |  |  |  |  |  |  |  |  |  |  |  |  |  |
| 000002 |  | Inicio/Acceso | milestone | 0d | 2024-06-13 | 2024-06-13 |  | 0d |  |  | 1.1 | 206 | Cronograma Gantt_7 | 2024-06-13 | 2024-06-13 | 2024-06-13 | 2024-06-12 | 2024-06-13 | 2024-06-13 | 2 | 2 |
| 000003 |  | Inicio Obras Preliminares | milestone | 0d | 2024-06-13 | 2024-06-13 | 000002 | 1d | 0d |  | 1.2 | 205 | Cronograma Gantt_7 | 2024-06-14 | 2024-06-14 | 2024-06-13 | 2024-06-13 | 2024-06-14 | 2024-06-13 | 3 | 3 |
| 000004 |  | Inicio Obras - Primera Etapa | milestone | 0d | 2024-07-26 | 2024-07-26 | 000042, 000040, 000039, 000038, 000033, 000032, 000031, 000002 FS+43d | 0d |  | start on or after 2024-07-26 | 1.3 | 204 | Cronograma Gantt_7 | 2024-07-27 | 2024-07-26 | 2024-07-26 | 2024-07-26 | 2024-07-26 | 2024-07-26 | 4 | 4 |
| 000005 |  | Inicio DI-PR-55-D | milestone | 0d | 2024-07-26 | 2024-07-26 | 000004 | 0d |  |  | 1.4 | 1262 | Cronograma Gantt_7 | 2024-07-27 | 2024-07-26 | 2024-07-26 | 2024-07-26 | 2024-07-26 | 2024-07-26 | 5 | 5 |
| 000007 |  | Inicio DI-PR-47-D | milestone | 0d | 2024-08-27 | 2024-08-27 | 000048 | 0d |  |  | 1.6 | 1267 | Cronograma Gantt_7 | 2024-08-28 | 2024-08-27 | 2024-08-27 | 2024-08-27 | 2024-08-27 | 2024-08-27 | 7 | 7 |
| 000009 |  | Inicio DI-PR-42-0-I | milestone | 0d | 2024-08-31 | 2024-08-31 | 000089 | 53d | 0d |  | 1.8 | 1265 | Cronograma Gantt_7 | 2024-09-01 | 2024-10-23 | 2024-08-31 | 2024-08-31 | 2024-10-23 | 2024-08-31 | 9 | 9 |
| 000011 |  | Inicio DI-PR-42-5-I | milestone | 0d | 2024-09-01 | 2024-09-01 | 000150 | 80d | 0d |  | 1.10 | 1268 | Cronograma Gantt_7 | 2024-09-02 | 2024-11-20 | 2024-09-01 | 2024-09-01 | 2024-11-20 | 2024-09-01 | 11 | 11 |
| 000012 |  | Fin DI-PR-42-5-I | milestone | 0d | 2024-10-12 | 2024-10-12 | 000206, 000205, 000203, 000180, 000176, 000175 | 80d |  |  | 1.11 | 1269 | Cronograma Gantt_7 | 2024-10-13 | 2024-12-31 | 2024-10-12 | 2024-10-12 | 2024-12-31 | 2024-10-12 | 12 | 12 |
| 000010 |  | Fin DI-PR-42-0-I | milestone | 0d | 2024-11-08 | 2024-11-08 | 000170, 000156, 000153, 000152 | 53d |  |  | 1.9 | 1264 | Cronograma Gantt_7 | 2024-11-09 | 2024-12-31 | 2024-11-08 | 2024-11-08 | 2024-12-31 | 2024-11-08 | 10 | 10 |
| 000006 |  | Fin DI-PR-55-D | milestone | 0d | 2024-11-22 | 2024-11-22 | 000086, 000075, 000063, 000057, 000055, 000052, 000051 | 39d |  |  | 1.5 | 1263 | Cronograma Gantt_7 | 2024-11-23 | 2024-12-31 | 2024-11-22 | 2024-11-22 | 2024-12-31 | 2024-11-22 | 6 | 6 |
| 000008 |  | Fin DI-PR-47-D | milestone | 0d | 2024-12-31 | 2024-12-31 | 000147, 000145, 000144, 000143, 000141, 000140, 000137, 000131, 000124, 000108, 000101, 000098, 000095, 000094, 000093 | 0d |  |  | 1.7 | 1266 | Cronograma Gantt_7 | 2025-01-01 | 2024-12-31 | 2024-12-31 | 2024-12-31 | 2024-12-31 | 2024-12-31 | 8 | 8 |
| 000013 |  | Inicio Paralización por Lluvia | milestone | 0d | 2024-12-31 | 2024-12-31 | 000211, 000209, 000036, 000034, 000012, 000010, 000008, 000006 | 0d |  |  | 1.12 | 207 | Cronograma Gantt_7 | 2025-01-01 | 2024-12-31 | 2024-12-31 | 2024-12-31 | 2024-12-31 | 2024-12-31 | 13 | 13 |
| 000014 |  | Fin Paralización | milestone | 0d | 2025-04-30 | 2025-04-30 | 000013 FS+120d | 0d |  |  | 1.13 | 208 | Cronograma Gantt_7 | 2025-05-01 | 2025-04-30 | 2025-04-30 | 2025-04-30 | 2025-04-30 | 2025-04-30 | 14 | 14 |
| 000015 |  | Inicio Segunda Etapa | milestone | 0d | 2025-05-01 | 2025-05-01 | 000014 FS+1d | 0d |  |  | 1.14 | 1277 | Cronograma Gantt_7 | 2025-05-02 | 2025-05-01 | 2025-05-01 | 2025-05-01 | 2025-05-01 | 2025-05-01 | 15 | 15 |
| 000016 |  | Inicio DI-PR-53-I | milestone | 0d | 2025-05-01 | 2025-05-01 | 000015 | 0d |  |  | 1.15 | 1278 | Cronograma Gantt_7 | 2025-05-02 | 2025-05-01 | 2025-05-01 | 2025-05-01 | 2025-05-01 | 2025-05-01 | 16 | 16 |
| 000018 |  | Inicio DI-PR-51-I | milestone | 0d | 2025-05-24 | 2025-05-24 | 000217 | 0d |  |  | 1.17 | 1280 | Cronograma Gantt_7 | 2025-05-25 | 2025-05-24 | 2025-05-24 | 2025-05-24 | 2025-05-24 | 2025-05-24 | 18 | 18 |
| 000020 |  | Inicio DI-PR-47bis-D / DE-PR-49bis-D | milestone | 0d | 2025-06-15 | 2025-06-15 | 000276 | 0d |  |  | 1.19 | 1282 | Cronograma Gantt_7 | 2025-06-16 | 2025-06-15 | 2025-06-15 | 2025-06-15 | 2025-06-15 | 2025-06-15 | 20 | 20 |
| 000022 |  | Inicio DI-PR-40A-D / DI-PR-40B-D | milestone | 0d | 2025-07-06 | 2025-07-06 | 000328 | 0d |  |  | 1.21 | 1287 | Cronograma Gantt_7 | 2025-07-07 | 2025-07-06 | 2025-07-06 | 2025-07-06 | 2025-07-06 | 2025-07-06 | 22 | 22 |
| 000024 |  | Inicio DI-PR-42-1-I / DI-PR-42-3-I | milestone | 0d | 2025-07-30 | 2025-07-30 | 000365 | 0d |  |  | 1.23 | 1289 | Cronograma Gantt_7 | 2025-07-31 | 2025-07-30 | 2025-07-30 | 2025-07-30 | 2025-07-30 | 2025-07-30 | 24 | 24 |
| 000026 |  | Inicio DE-PR-39-I | milestone | 0d | 2025-08-01 | 2025-08-01 | 000407 | 0d |  |  | 1.25 | 1293 | Cronograma Gantt_7 | 2025-08-02 | 2025-08-01 | 2025-08-01 | 2025-08-01 | 2025-08-01 | 2025-08-01 | 26 | 26 |
| 000017 |  | Fin DI-PR-53-I | milestone | 0d | 2025-08-06 | 2025-08-06 | 000270, 000269, 000265, 000262, 000258, 000252, 000251, 000235, 000234, 000228, 000225, 000224, 000222, 000221, 000220, 000219, 000218 | 98d |  |  | 1.16 | 1279 | Cronograma Gantt_7 | 2025-08-07 | 2025-11-12 | 2025-08-06 | 2025-08-06 | 2025-11-12 | 2025-08-06 | 17 | 17 |
| 000019 |  | Fin DI-PR-51-I | milestone | 0d | 2025-10-04 | 2025-10-04 | 000323, 000322, 000321, 000320, 000319, 000317, 000312, 000307, 000306, 000290, 000280, 000279, 000278, 000277 | 39d |  |  | 1.18 | 1281 | Cronograma Gantt_7 | 2025-10-05 | 2025-11-12 | 2025-10-04 | 2025-10-04 | 2025-11-12 | 2025-10-04 | 19 | 19 |
| 000023 |  | Fin DI-PR-40A-D / DI-PR-40B-D | milestone | 0d | 2025-10-19 | 2025-10-19 | 000404, 000386, 000383, 000382, 000375, 000372, 000371, 000369, 000368, 000366 | 24d |  |  | 1.22 | 1290 | Cronograma Gantt_7 | 2025-10-20 | 2025-11-12 | 2025-10-19 | 2025-10-19 | 2025-11-12 | 2025-10-19 | 23 | 23 |
| 000021 |  | Fin DI-PR-47bis-D / DE-PR-49bis-D | milestone | 0d | 2025-10-25 | 2025-10-25 | 000347, 000346, 000340, 000339, 000337, 000336, 000333, 000332, 000331, 000330 | 18d |  |  | 1.20 | 1288 | Cronograma Gantt_7 | 2025-10-26 | 2025-11-12 | 2025-10-25 | 2025-10-25 | 2025-11-12 | 2025-10-25 | 21 | 21 |
| 000027 |  | Fin Inicio DE-PR-39-I | milestone | 0d | 2025-11-08 | 2025-11-08 | 000507, 000506, 000503, 000501, 000500, 000497, 000492, 000469, 000468, 000461, 000460, 000457, 000454, 000453, 000452, 000451 | 4d |  |  | 1.26 | 1295 | Cronograma Gantt_7 | 2025-11-09 | 2025-11-12 | 2025-11-08 | 2025-11-08 | 2025-11-12 | 2025-11-08 | 27 | 27 |
| 000025 |  | Fin DI-PR-42-1-I / DI-PR-42-3-I | milestone | 0d | 2025-11-12 | 2025-11-12 | 000444, 000427, 000426, 000425, 000424, 000420, 000413, 000412, 000411 | 0d |  |  | 1.24 | 1292 | Cronograma Gantt_7 | 2025-11-13 | 2025-11-12 | 2025-11-12 | 2025-11-12 | 2025-11-12 | 2025-11-12 | 25 | 25 |
| 000028 |  | Fin Segunda Etapa | milestone | 0d | 2025-11-12 | 2025-11-12 | 000037, 000035, 000027, 000025, 000023, 000021, 000019, 000017 | 0d |  |  | 1.27 | 1296 | Cronograma Gantt_7 | 2025-11-13 | 2025-11-12 | 2025-11-12 | 2025-11-12 | 2025-11-12 | 2025-11-12 | 28 | 28 |
| 000029 |  | Culminación de Obra | milestone | 0d | 2025-11-12 | 2025-11-12 | 000508, 000028 | 0d |  |  | 1.28 | 1300 | Cronograma Gantt_7 | 2025-11-13 | 2025-11-12 | 2025-11-12 | 2025-11-12 | 2025-11-12 | 2025-11-12 | 29 | 29 |

| ID | WBS | Activity | Duration | Start | Finish | Predecessors | Total float | Free float | MSP Outline Number | MSP Unique ID | MSP Project Name | Imported Early Start | Imported Late Start | Imported Start | Imported Early Finish | Imported Late Finish | Imported Finish | MSP ID | MSP Task Order |
| --- | --- | --- | --- | --- | --- | --- | --- | --- | --- | --- | --- | --- | --- | --- | --- | --- | --- | --- | --- |
|  | 000030 | **Obras Provisionales** |  | 2024-06-13 | 2025-11-12 |  |  |  |  |  |  |  |  |  |  |  |  |  |  |
| 000031 |  | Campamento Provisional de Obra | 42d | 2024-06-13 | 2024-07-25 | 000003 | 1d |  | 2.1 | 95 | Cronograma Gantt_7 | 2024-06-13 | 2024-06-14 | 2024-06-13 | 2024-07-25 | 2024-07-26 | 2024-07-25 | 31 | 31 |
| 000032 |  | Movilizacion y Desmovilizacion de Maquinaria Pesada | 1d | 2024-06-13 | 2024-06-14 | 000003 | 42d |  | 2.2 | 96 | Cronograma Gantt_7 | 2024-06-13 | 2024-07-25 | 2024-06-13 | 2024-06-14 | 2024-07-26 | 2024-06-14 | 32 | 32 |
| 000033 |  | Mejoramiento y Habilitacion de Caminos de Acceso | 42d | 2024-06-13 | 2024-07-25 | 000003 | 1d |  | 2.3 | 97 | Cronograma Gantt_7 | 2024-06-13 | 2024-06-14 | 2024-06-13 | 2024-07-25 | 2024-07-26 | 2024-07-25 | 33 | 33 |
| 000039 |  | Tuberia HDPE Corrugada f=600mm, para Caminos de Acceso (o similar) | 42d | 2024-06-13 | 2024-07-25 | 000003 | 1d |  | 2.9 | 101 | Cronograma Gantt_7 | 2024-06-13 | 2024-06-14 | 2024-06-13 | 2024-07-25 | 2024-07-26 | 2024-07-25 | 39 | 39 |
| 000040 |  | Tuberia HDPE Corrugada f=1000mm, para Caminos de Acceso (o similar) | 42d | 2024-06-13 | 2024-07-25 | 000003 | 1d |  | 2.10 | 102 | Cronograma Gantt_7 | 2024-06-13 | 2024-06-14 | 2024-06-13 | 2024-07-25 | 2024-07-26 | 2024-07-25 | 40 | 40 |
| 000038 |  | Habilitacion de Plataformas | 30d | 2024-06-23 | 2024-07-23 | 000002 FS+10d | 3d |  | 2.8 | 100 | Cronograma Gantt_7 | 2024-06-23 | 2024-06-26 | 2024-06-23 | 2024-07-23 | 2024-07-26 | 2024-07-23 | 38 | 38 |
| 000034 |  | Limpieza Manual de Material Vegetal y de Residuos - 1era etapa | 158d | 2024-07-26 | 2024-12-31 | 000004 | 0d |  | 2.4 | 98 | Cronograma Gantt_7 | 2024-07-26 | 2024-07-26 | 2024-07-26 | 2024-12-31 | 2024-12-31 | 2024-12-31 | 34 | 34 |
| 000036 |  | Mantenimiento de Caminos de Acceso - 1era etapa | 158d | 2024-07-26 | 2024-12-31 | 000004 | 0d |  | 2.6 | 99 | Cronograma Gantt_7 | 2024-07-26 | 2024-07-26 | 2024-07-26 | 2024-12-31 | 2024-12-31 | 2024-12-31 | 36 | 36 |
| 000035 |  | Limpieza Manual de Material Vegetal y de Residuos - 2da etapa | 195d | 2025-05-01 | 2025-11-12 | 000015 | 0d |  | 2.5 | 1298 | Cronograma Gantt_7 | 2025-05-01 | 2025-05-01 | 2025-05-01 | 2025-11-12 | 2025-11-12 | 2025-11-12 | 35 | 35 |
| 000037 |  | Mantenimiento de Caminos de Acceso - 2da etapa | 195d | 2025-05-01 | 2025-11-12 | 000015 | 0d |  | 2.7 | 1299 | Cronograma Gantt_7 | 2025-05-01 | 2025-05-01 | 2025-05-01 | 2025-11-12 | 2025-11-12 | 2025-11-12 | 37 | 37 |
|  | 000041 | **Topografia** |  | 2024-06-18 | 2024-07-23 |  |  |  |  |  |  |  |  |  |  |  |  |  |  |
| 000042 |  | Trazo y Replanteo Inicial | 35d | 2024-06-18 | 2024-07-23 | 000002 FS+5d | 3d |  | 3.1 | 106 | Cronograma Gantt_7 | 2024-06-18 | 2024-06-21 | 2024-06-18 | 2024-07-23 | 2024-07-26 | 2024-07-23 | 42 | 42 |
|  | 000043 | **PRIMERA ETAPA** |  | 2024-07-26 | 2024-12-31 |  |  |  |  |  |  |  |  |  |  |  |  |  |  |
|  | 000044 | **DI-PR-55-D** |  | 2024-07-26 | 2024-11-22 |  |  |  |  |  |  |  |  |  |  |  |  |  |  |
|  | 000045 | **Excavaciones** |  | 2024-07-26 | 2024-10-01 |  |  |  |  |  |  |  |  |  |  |  |  |  |  |
| 000046 |  | Desbroce | 3d | 2024-07-26 | 2024-07-29 | 000005 | 0d |  | 4.1.1.1 | 108 | Cronograma Gantt_7 | 2024-07-26 | 2024-07-26 | 2024-07-26 | 2024-07-29 | 2024-07-29 | 2024-07-29 | 46 | 46 |
| 000052 |  | Conformacion de Material Excedente en DMO | 6d | 2024-07-28 | 2024-08-03 | 000067 SS+1d | 150d | 111d | 4.1.1.7 | 114 | Cronograma Gantt_7 | 2024-07-28 | 2024-12-25 | 2024-07-28 | 2024-08-03 | 2024-12-31 | 2024-08-03 | 52 | 52 |
| 000047 |  | Remocion de Dique Existente | 11d | 2024-07-29 | 2024-08-09 | 000046 | 0d |  | 4.1.1.2 | 109 | Cronograma Gantt_7 | 2024-07-29 | 2024-07-29 | 2024-07-29 | 2024-08-09 | 2024-08-09 | 2024-08-09 | 47 | 47 |
| 000048 |  | Excavacion de Cimentacion | 18d | 2024-08-09 | 2024-08-27 | 000047 | 0d |  | 4.1.1.3 | 110 | Cronograma Gantt_7 | 2024-08-09 | 2024-08-09 | 2024-08-09 | 2024-08-27 | 2024-08-27 | 2024-08-27 | 48 | 48 |
| 000049 |  | Perfilado y Conformacion de Plataforma de Fundacion | 9d | 2024-08-11 | 2024-08-20 | 000048 SS+2d | 39d | 0d | 4.1.1.4 | 111 | Cronograma Gantt_7 | 2024-08-11 | 2024-09-19 | 2024-08-11 | 2024-08-20 | 2024-09-28 | 2024-08-20 | 49 | 49 |
| 000050 |  | Excavacion de Uña | 19d | 2024-08-11 | 2024-08-30 | 000048 SS+2d | 81d | 42d | 4.1.1.5 | 112 | Cronograma Gantt_7 | 2024-08-11 | 2024-10-31 | 2024-08-11 | 2024-08-30 | 2024-11-19 | 2024-08-30 | 50 | 50 |
| 000051 |  | Conformacion de Material Excedente en DME | 39d | 2024-08-23 | 2024-10-01 | 000069 SS+1d | 91d | 52d | 4.1.1.6 | 113 | Cronograma Gantt_7 | 2024-08-23 | 2024-11-22 | 2024-08-23 | 2024-10-01 | 2024-12-31 | 2024-10-01 | 51 | 51 |
|  | 000053 | **Rellenos** |  | 2024-08-20 | 2024-10-18 |  |  |  |  |  |  |  |  |  |  |  |  |  |  |
| 000054 |  | Relleno con Material Granular (incluye extraccion de material, zarandeo y combinado) | 27d | 2024-08-20 | 2024-09-16 | 000049 | 39d | 0d | 4.1.2.1 | 118 | Cronograma Gantt_7 | 2024-08-20 | 2024-09-28 | 2024-08-20 | 2024-09-16 | 2024-10-25 | 2024-09-16 | 54 | 54 |
| 000056 |  | Perfilado de Talud Dique | 13d | 2024-09-16 | 2024-09-29 | 000054 | 39d | 0d | 4.1.2.3 | 121 | Cronograma Gantt_7 | 2024-09-16 | 2024-10-25 | 2024-09-16 | 2024-09-29 | 2024-11-07 | 2024-09-29 | 56 | 56 |
| 000057 |  | Grava para Drenaje | 1d | 2024-09-29 | 2024-09-30 | 000056 | 92d | 53d | 4.1.2.4 | 123 | Cronograma Gantt_7 | 2024-09-29 | 2024-12-30 | 2024-09-29 | 2024-09-30 | 2024-12-31 | 2024-09-30 | 57 | 57 |
| 000055 |  | Relleno Afirmado | 1d | 2024-10-17 | 2024-10-18 | 000071, 000060 | 74d | 35d | 4.1.2.2 | 120 | Cronograma Gantt_7 | 2024-10-17 | 2024-12-30 | 2024-10-17 | 2024-10-18 | 2024-12-31 | 2024-10-18 | 55 | 55 |

| ID | WBS | Activity | Duration | Start | Finish | Predecessors | Total float | Free float | MSP Outline Number | MSP Unique ID | MSP Project Name | Imported Early Start | Imported Late Start | Imported Start | Imported Early Finish | Imported Late Finish | Imported Finish | MSP ID | MSP Task Order |
| --- | --- | --- | --- | --- | --- | --- | --- | --- | --- | --- | --- | --- | --- | --- | --- | --- | --- | --- | --- |
|  | 000058 | **Geotextil** |  | 2024-09-29 | 2024-10-17 |  |  |  |  |  |  |  |  |  |  |  |  |  |  |
| 000059 |  | Instalacion de Geotextil 400gr/m2 | 12d | 2024-09-29 | 2024-10-11 | 000077, 000056 | 39d | 0d | 4.1.3.1 | 126 | Cronograma Gantt_7 | 2024-09-29 | 2024-11-07 | 2024-09-29 | 2024-10-11 | 2024-11-19 | 2024-10-11 | 59 | 59 |
| 000060 |  | Zanja de Anclaje | 6d | 2024-10-11 | 2024-10-17 | 000059 | 74d | 0d | 4.1.3.2 | 127 | Cronograma Gantt_7 | 2024-10-11 | 2024-12-24 | 2024-10-11 | 2024-10-17 | 2024-12-30 | 2024-10-17 | 60 | 60 |
|  | 000061 | **Colocacion de Roca** |  | 2024-08-09 | 2024-11-22 |  |  |  |  |  |  |  |  |  |  |  |  |  |  |
| 000064 |  | Extraccion de Rocas Reutilizables | 14d | 2024-08-09 | 2024-08-23 | 000047 | 105d | 66d | 4.1.4.3 | 132 | Cronograma Gantt_7 | 2024-08-09 | 2024-11-22 | 2024-08-09 | 2024-08-23 | 2024-12-06 | 2024-08-23 | 64 | 64 |
| 000062 |  | Colocacion de Roca en Uña | 17d | 2024-10-11 | 2024-10-28 | 000059, 000050 | 39d | 0d | 4.1.4.1 | 130 | Cronograma Gantt_7 | 2024-10-11 | 2024-11-19 | 2024-10-11 | 2024-10-28 | 2024-12-06 | 2024-10-28 | 62 | 62 |
| 000063 |  | Colocacion de Roca en Talud | 25d | 2024-10-28 | 2024-11-22 | 000064, 000062 | 39d | 0d | 4.1.4.2 | 131 | Cronograma Gantt_7 | 2024-10-28 | 2024-12-06 | 2024-10-28 | 2024-11-22 | 2024-12-31 | 2024-11-22 | 63 | 63 |
|  | 000065 | **Transportes** |  | 2024-07-27 | 2024-10-11 |  |  |  |  |  |  |  |  |  |  |  |  |  |  |
| 000066 |  | Transporte de Material Organico (a DMO) D<=1km | 24d | 2024-07-27 | 2024-08-20 | 000046 SS+1d | 112d | 0d | 4.1.5.1 | 141 | Cronograma Gantt_7 | 2024-07-27 | 2024-11-16 | 2024-07-27 | 2024-08-20 | 2024-12-10 | 2024-08-20 | 66 | 66 |
| 000067 |  | Transporte de Material Organico (a DMO) D>1km | 35d | 2024-07-27 | 2024-08-31 | 000066 SS | 112d | 0d | 4.1.5.2 | 142 | Cronograma Gantt_7 | 2024-07-27 | 2024-11-16 | 2024-07-27 | 2024-08-31 | 2024-12-21 | 2024-08-31 | 67 | 67 |
| 000068 |  | Transporte de Material Excedente D<=1km | 40d | 2024-07-30 | 2024-09-08 | 000047 SS+1d | 80d | 0d | 4.1.5.3 | 143 | Cronograma Gantt_7 | 2024-07-30 | 2024-10-18 | 2024-07-30 | 2024-09-08 | 2024-11-27 | 2024-09-08 | 68 | 68 |
| 000069 |  | Transporte de Material Excedente D>1km | 18d | 2024-08-22 | 2024-09-09 | 000068 FS-17d | 80d | 0d | 4.1.5.4 | 144 | Cronograma Gantt_7 | 2024-08-22 | 2024-11-10 | 2024-08-22 | 2024-09-09 | 2024-11-28 | 2024-09-09 | 69 | 69 |
| 000074 |  | Transporte de Material de Prestamo Cantera de Rio (Cuerpo de Terraplen) D<=1km | 15d | 2024-08-31 | 2024-09-15 | 000067 | 112d | 0d | 4.1.5.9 | 149 | Cronograma Gantt_7 | 2024-08-31 | 2024-12-21 | 2024-08-31 | 2024-09-15 | 2025-01-05 | 2024-09-15 | 74 | 74 |
| 000075 |  | Transporte de Material de Prestamo Cantera de Rio (Cuerpo de Terraplen) D>1km | 10d | 2024-08-31 | 2024-09-10 | 000074 SS | 112d | 73d | 4.1.5.10 | 150 | Cronograma Gantt_7 | 2024-08-31 | 2024-12-21 | 2024-08-31 | 2024-09-10 | 2024-12-31 | 2024-09-10 | 75 | 75 |
| 000072 |  | Transporte de Roca D<=1km | 28d | 2024-09-01 | 2024-09-29 | 000056 FF | 51d | 0d | 4.1.5.7 | 147 | Cronograma Gantt_7 | 2024-09-01 | 2024-10-22 | 2024-09-01 | 2024-09-29 | 2024-11-19 | 2024-09-29 | 72 | 72 |
| 000073 |  | Transporte de Roca D>1km | 15d | 2024-09-01 | 2024-09-16 | 000072 SS | 51d | 0d | 4.1.5.8 | 148 | Cronograma Gantt_7 | 2024-09-01 | 2024-10-22 | 2024-09-01 | 2024-09-16 | 2024-11-06 | 2024-09-16 | 73 | 73 |
| 000070 |  | Transporte de Material de Prestamo (Afirmado) D<=1km | 24d | 2024-09-09 | 2024-10-03 | 000069 | 80d | 0d | 4.1.5.5 | 145 | Cronograma Gantt_7 | 2024-09-09 | 2024-11-28 | 2024-09-09 | 2024-10-03 | 2024-12-22 | 2024-10-03 | 70 | 70 |
| 000071 |  | Transporte de Material de Prestamo (Afirmado) D>1km | 32d | 2024-09-09 | 2024-10-11 | 000070 SS | 80d | 6d | 4.1.5.6 | 146 | Cronograma Gantt_7 | 2024-09-09 | 2024-11-28 | 2024-09-09 | 2024-10-11 | 2024-12-30 | 2024-10-11 | 71 | 71 |
| 000076 |  | Transporte de Material Seleccionado para Zanja D<=1km | 1d | 2024-09-16 | 2024-09-17 | 000073 | 51d | 0d | 4.1.5.11 | 151 | Cronograma Gantt_7 | 2024-09-16 | 2024-11-06 | 2024-09-16 | 2024-09-17 | 2024-11-07 | 2024-09-17 | 76 | 76 |
| 000077 |  | Transporte de Material Seleccionado para Zanja D>1km | 1d | 2024-09-16 | 2024-09-17 | 000076 SS | 51d | 12d | 4.1.5.12 | 152 | Cronograma Gantt_7 | 2024-09-16 | 2024-11-06 | 2024-09-16 | 2024-09-17 | 2024-11-07 | 2024-09-17 | 77 | 77 |
|  | 000078 | **Obras Civiles** |  | 2024-08-27 | 2024-09-21 |  |  |  |  |  |  |  |  |  |  |  |  |  |  |
| 000079 |  | Concreto de Nivelacion (f'c=100 kg/cm2) | 1d | 2024-08-27 | 2024-08-28 | 000048 | 101d | 0d | 4.1.6.1 | 188 | Cronograma Gantt_7 | 2024-08-27 | 2024-12-06 | 2024-08-27 | 2024-08-28 | 2024-12-07 | 2024-08-28 | 79 | 79 |
| 000084 |  | Acero de refuerzo f'y=4200kg/cm2 | 6d | 2024-08-28 | 2024-09-03 | 000079 | 101d | 0d | 4.1.6.6 | 193 | Cronograma Gantt_7 | 2024-08-28 | 2024-12-07 | 2024-08-28 | 2024-09-03 | 2024-12-13 | 2024-09-03 | 84 | 84 |
| 000080 |  | Concreto Clase C (f'c=280 kg/cm2) Premezclado - Cimientos reforzados | 1d | 2024-08-30 | 2024-08-31 | 000084 SS+2d | 101d | 0d | 4.1.6.2 | 189 | Cronograma Gantt_7 | 2024-08-30 | 2024-12-09 | 2024-08-30 | 2024-08-31 | 2024-12-10 | 2024-08-31 | 80 | 80 |
| 000083 |  | Encofrado y Desencofrado Cara Oculta | 2d | 2024-09-04 | 2024-09-06 | 000080 FS+4d | 432d |  | 4.1.6.5 | 192 | Cronograma Gantt_7 | 2024-09-04 | 2025-11-10 | 2024-09-04 | 2024-09-06 | 2025-11-12 | 2024-09-06 | 83 | 83 |
| 000082 |  | Encofrado y Desencofrado Caravista | 8d | 2024-09-05 | 2024-09-13 | 000080 FS+5d | 101d | 0d | 4.1.6.4 | 191 | Cronograma Gantt_7 | 2024-09-05 | 2024-12-15 | 2024-09-05 | 2024-09-13 | 2024-12-23 | 2024-09-13 | 82 | 82 |
| 000081 |  | Concreto Clase C (f'c=280 kg/cm2) Premezclado - Muros de contencion | 1d | 2024-09-13 | 2024-09-14 | 000082 | 101d | 0d | 4.1.6.3 | 190 | Cronograma Gantt_7 | 2024-09-13 | 2024-12-23 | 2024-09-13 | 2024-09-14 | 2024-12-24 | 2024-09-14 | 81 | 81 |
| 000085 |  | Junta de dilatación | 1d | 2024-09-14 | 2024-09-15 | 000081 | 101d | 0d | 4.1.6.7 | 194 | Cronograma Gantt_7 | 2024-09-14 | 2024-12-24 | 2024-09-14 | 2024-09-15 | 2024-12-25 | 2024-09-15 | 85 | 85 |
| 000086 |  | Pintura bituminosa | 6d | 2024-09-15 | 2024-09-21 | 000085 | 101d | 62d | 4.1.6.8 | 195 | Cronograma Gantt_7 | 2024-09-15 | 2024-12-25 | 2024-09-15 | 2024-09-21 | 2024-12-31 | 2024-09-21 | 86 | 86 |

| ID | WBS | Activity | Duration | Start | Finish | Predecessors | Total float | Free float | MSP Outline Number | MSP Unique ID | MSP Project Name | Imported Early Start | Imported Late Start | Imported Start | Imported Early Finish | Imported Late Finish | Imported Finish | MSP ID | MSP Task Order |
| --- | --- | --- | --- | --- | --- | --- | --- | --- | --- | --- | --- | --- | --- | --- | --- | --- | --- | --- | --- |
|  | 000087 | **DI-PR-47-D** |  | 2024-08-27 | 2024-12-31 |  |  |  |  |  |  |  |  |  |  |  |  |  |  |
|  | 000088 | **Excavaciones** |  | 2024-08-27 | 2024-10-18 |  |  |  |  |  |  |  |  |  |  |  |  |  |  |
| 000089 |  | Desbroce | 4d | 2024-08-27 | 2024-08-31 | 000007 | 0d |  | 4.2.1.1 | 214 | Cronograma Gantt_7 | 2024-08-27 | 2024-08-27 | 2024-08-27 | 2024-08-31 | 2024-08-31 | 2024-08-31 | 89 | 89 |
| 000090 |  | Excavacion de Cimentacion | 12d | 2024-08-29 | 2024-09-10 | 000089 FS-2d | 0d |  | 4.2.1.2 | 216 | Cronograma Gantt_7 | 2024-08-29 | 2024-08-29 | 2024-08-29 | 2024-09-10 | 2024-09-10 | 2024-09-10 | 90 | 90 |
| 000094 |  | Conformacion de Material Excedente en DMO | 7d | 2024-08-29 | 2024-09-05 | 000111 SS+1d | 117d |  | 4.2.1.6 | 220 | Cronograma Gantt_7 | 2024-08-29 | 2024-12-24 | 2024-08-29 | 2024-09-05 | 2024-12-31 | 2024-09-05 | 94 | 94 |
| 000091 |  | Perfilado y Conformacion de Plataforma de Fundacion | 16d | 2024-08-31 | 2024-09-16 | 000090 SS+2d | 17d | 0d | 4.2.1.3 | 217 | Cronograma Gantt_7 | 2024-08-31 | 2024-09-17 | 2024-08-31 | 2024-09-16 | 2024-10-03 | 2024-09-16 | 91 | 91 |
| 000092 |  | Excavacion de Uña | 40d | 2024-08-31 | 2024-10-10 | 000090 SS+2d | 0d |  | 4.2.1.4 | 218 | Cronograma Gantt_7 | 2024-08-31 | 2024-08-31 | 2024-08-31 | 2024-10-10 | 2024-10-10 | 2024-10-10 | 92 | 92 |
| 000093 |  | Conformacion de Material Excedente en DME | 48d | 2024-08-31 | 2024-10-18 | 000113 SS+1d | 74d |  | 4.2.1.5 | 219 | Cronograma Gantt_7 | 2024-08-31 | 2024-11-13 | 2024-08-31 | 2024-10-18 | 2024-12-31 | 2024-10-18 | 93 | 93 |
| 000095 |  | Excavacion Localizada - Sobreexcavacion | 25d | 2024-09-04 | 2024-09-29 | 000090 SS+6d | 93d |  | 4.2.1.7 | 221 | Cronograma Gantt_7 | 2024-09-04 | 2024-12-06 | 2024-09-04 | 2024-09-29 | 2024-12-31 | 2024-09-29 | 95 | 95 |
|  | 000096 | **Rellenos** |  | 2024-09-04 | 2024-12-09 |  |  |  |  |  |  |  |  |  |  |  |  |  |  |
| 000097 |  | Relleno con Material Granular (incluye extraccion de material, zarandeo y combinado) | 20d | 2024-09-04 | 2024-09-24 | 000091 SS+4d | 17d | 0d | 4.2.2.1 | 224 | Cronograma Gantt_7 | 2024-09-04 | 2024-09-21 | 2024-09-04 | 2024-09-24 | 2024-10-11 | 2024-09-24 | 97 | 97 |
| 000101 |  | Relleno con Material Seleccionado (incluye extraccion de material, zarandeo y combinado) | 13d | 2024-09-06 | 2024-09-19 | 000097 SS+2d | 103d |  | 4.2.2.5 | 228 | Cronograma Gantt_7 | 2024-09-06 | 2024-12-18 | 2024-09-06 | 2024-09-19 | 2024-12-31 | 2024-09-19 | 101 | 101 |
| 000100 |  | Perfilado de Talud Dique | 7d | 2024-09-14 | 2024-09-21 | 000097 SS+10d | 17d | 0d | 4.2.2.4 | 227 | Cronograma Gantt_7 | 2024-09-14 | 2024-10-01 | 2024-09-14 | 2024-09-21 | 2024-10-08 | 2024-09-21 | 100 | 100 |
| 000102 |  | Grava para Drenaje | 2d | 2024-09-21 | 2024-09-23 | 000100 | 415d |  | 4.2.2.6 | 229 | Cronograma Gantt_7 | 2024-09-21 | 2025-11-10 | 2024-09-21 | 2024-09-23 | 2025-11-12 | 2024-09-23 | 102 | 102 |
| 000099 |  | Relleno Afirmado | 2d | 2024-11-21 | 2024-11-23 | 000115, 000105 | 0d |  | 4.2.2.3 | 226 | Cronograma Gantt_7 | 2024-11-21 | 2024-11-21 | 2024-11-21 | 2024-11-23 | 2024-11-23 | 2024-11-23 | 99 | 99 |
| 000098 |  | Relleno sin Compactar | 4d | 2024-12-05 | 2024-12-09 | 000107 | 22d |  | 4.2.2.2 | 225 | Cronograma Gantt_7 | 2024-12-05 | 2024-12-27 | 2024-12-05 | 2024-12-09 | 2024-12-31 | 2024-12-09 | 98 | 98 |
|  | 000103 | **Geotextil** |  | 2024-10-10 | 2024-11-09 |  |  |  |  |  |  |  |  |  |  |  |  |  |  |
| 000104 |  | Instalacion de Geotextil 400gr/m2 | 15d | 2024-10-10 | 2024-10-25 | 000092 | 0d |  | 4.2.3.1 | 232 | Cronograma Gantt_7 | 2024-10-10 | 2024-10-10 | 2024-10-10 | 2024-10-25 | 2024-10-25 | 2024-10-25 | 104 | 104 |
| 000105 |  | Zanja de Anclaje | 15d | 2024-10-25 | 2024-11-09 | 000121, 000104 | 0d |  | 4.2.3.2 | 233 | Cronograma Gantt_7 | 2024-10-25 | 2024-10-25 | 2024-10-25 | 2024-11-09 | 2024-11-09 | 2024-11-09 | 105 | 105 |
|  | 000106 | **Colocacion de Roca** |  | 2024-11-23 | 2024-12-31 |  |  |  |  |  |  |  |  |  |  |  |  |  |  |
| 000107 |  | Colocacion de Roca en Uña | 12d | 2024-11-23 | 2024-12-05 | 000117, 000099 | 0d |  | 4.2.4.1 | 236 | Cronograma Gantt_7 | 2024-11-23 | 2024-11-23 | 2024-11-23 | 2024-12-05 | 2024-12-05 | 2024-12-05 | 107 | 107 |
| 000108 |  | Colocacion de Roca en Talud | 28d | 2024-12-03 | 2024-12-31 | 000107 SS+10d | 0d |  | 4.2.4.2 | 237 | Cronograma Gantt_7 | 2024-12-03 | 2024-12-03 | 2024-12-03 | 2024-12-31 | 2024-12-31 | 2024-12-31 | 108 | 108 |
|  | 000109 | **Transportes** |  | 2024-08-28 | 2024-11-21 |  |  |  |  |  |  |  |  |  |  |  |  |  |  |
| 000110 |  | Transporte de Material Organico (a DMO) D<=1km | 14d | 2024-08-28 | 2024-09-11 | 000089 SS+1d | 117d | 0d | 4.2.5.1 | 247 | Cronograma Gantt_7 | 2024-08-28 | 2024-12-23 | 2024-08-28 | 2024-09-11 | 2025-01-06 | 2024-09-11 | 110 | 110 |
| 000111 |  | Transporte de Material Organico (a DMO) D>1km | 21d | 2024-08-28 | 2024-09-18 | 000110 SS | 117d | 0d | 4.2.5.2 | 248 | Cronograma Gantt_7 | 2024-08-28 | 2024-12-23 | 2024-08-28 | 2024-09-18 | 2025-01-13 | 2024-09-18 | 111 | 111 |
| 000112 |  | Transporte de Material Excedente D<=1km | 49d | 2024-08-30 | 2024-10-18 | 000090 SS+1d | 74d | 0d | 4.2.5.3 | 249 | Cronograma Gantt_7 | 2024-08-30 | 2024-11-12 | 2024-08-30 | 2024-10-18 | 2024-12-31 | 2024-10-18 | 112 | 112 |
| 000113 |  | Transporte de Material Excedente D>1km | 83d | 2024-08-30 | 2024-11-21 | 000112 SS | 74d | 0d | 4.2.5.4 | 250 | Cronograma Gantt_7 | 2024-08-30 | 2024-11-12 | 2024-08-30 | 2024-11-21 | 2025-02-03 | 2024-11-21 | 113 | 113 |
| 000118 |  | Transporte de Material de Prestamo Cantera de Rio (Cuerpo de Terraplen) D<=1km | 30d | 2024-09-09 | 2024-10-09 | 000090 SS+11d | 379d | 0d | 4.2.5.9 | 255 | Cronograma Gantt_7 | 2024-09-09 | 2025-09-23 | 2024-09-09 | 2024-10-09 | 2025-10-23 | 2024-10-09 | 118 | 118 |
| 000116 |  | Transporte de Roca D<=1km | 30d | 2024-09-21 | 2024-10-21 | 000100 | 17d | 0d | 4.2.5.7 | 253 | Cronograma Gantt_7 | 2024-09-21 | 2024-10-08 | 2024-09-21 | 2024-10-21 | 2024-11-07 | 2024-10-21 | 116 | 116 |
| 000117 |  | Transporte de Roca D>1km | 45d | 2024-09-22 | 2024-11-06 | 000116 SS+1d | 17d |  | 4.2.5.8 | 254 | Cronograma Gantt_7 | 2024-09-22 | 2024-10-09 | 2024-09-22 | 2024-11-06 | 2024-11-23 | 2024-11-06 | 117 | 117 |
| 000119 |  | Transporte de Material de Prestamo Cantera de Rio (Cuerpo de Terraplen) D>1km | 20d | 2024-10-09 | 2024-10-29 | 000118 | 379d |  | 4.2.5.10 | 256 | Cronograma Gantt_7 | 2024-10-09 | 2025-10-23 | 2024-10-09 | 2024-10-29 | 2025-11-12 | 2024-10-29 | 119 | 119 |
| 000120 |  | Transporte de Material Seleccionado para Zanja D<=1km | 1d | 2024-10-10 | 2024-10-11 | 000092 | 14d | 0d | 4.2.5.11 | 257 | Cronograma Gantt_7 | 2024-10-10 | 2024-10-24 | 2024-10-10 | 2024-10-11 | 2024-10-25 | 2024-10-11 | 120 | 120 |
| 000121 |  | Transporte de Material Seleccionado para Zanja D>1km | 1d | 2024-10-10 | 2024-10-11 | 000120 SS | 14d |  | 4.2.5.12 | 258 | Cronograma Gantt_7 | 2024-10-10 | 2024-10-24 | 2024-10-10 | 2024-10-11 | 2024-10-25 | 2024-10-11 | 121 | 121 |
| 000114 |  | Transporte de Material de Prestamo (Afirmado) D<=1km | 8d | 2024-11-09 | 2024-11-17 | 000105 | 0d |  | 4.2.5.5 | 251 | Cronograma Gantt_7 | 2024-11-09 | 2024-11-09 | 2024-11-09 | 2024-11-17 | 2024-11-17 | 2024-11-17 | 114 | 114 |
| 000115 |  | Transporte de Material de Prestamo (Afirmado) D>1km | 12d | 2024-11-09 | 2024-11-21 | 000114 SS | 0d |  | 4.2.5.6 | 252 | Cronograma Gantt_7 | 2024-11-09 | 2024-11-09 | 2024-11-09 | 2024-11-21 | 2024-11-21 | 2024-11-21 | 115 | 115 |

| ID | WBS | Activity | Duration | Start | Finish | Predecessors | Total float | Free float | MSP Outline Number | MSP Unique ID | MSP Project Name | Imported Early Start | Imported Late Start | Imported Start | Imported Early Finish | Imported Late Finish | Imported Finish | MSP ID | MSP Task Order |
| --- | --- | --- | --- | --- | --- | --- | --- | --- | --- | --- | --- | --- | --- | --- | --- | --- | --- | --- | --- |
|  | 000122 | **Obras Civiles (Interferencias)** |  | 2024-09-10 | 2024-10-28 |  |  |  |  |  |  |  |  |  |  |  |  |  |  |
| 000123 |  | Trazo y replanteo de interferencia | 1d | 2024-09-10 | 2024-09-11 | 000090 | 64d | 0d | 4.2.6.1 | 260 | Cronograma Gantt_7 | 2024-09-10 | 2024-11-13 | 2024-09-10 | 2024-09-11 | 2024-11-14 | 2024-09-11 | 123 | 123 |
| 000124 |  | Desvío provisional con tubería | 2d | 2024-09-11 | 2024-09-13 | 000123 | 109d |  | 4.2.6.2 | 261 | Cronograma Gantt_7 | 2024-09-11 | 2024-12-29 | 2024-09-11 | 2024-09-13 | 2024-12-31 | 2024-09-13 | 124 | 124 |
| 000125 |  | Desvío provisional en tierras | 5d | 2024-09-11 | 2024-09-16 | 000123 | 64d | 0d | 4.2.6.3 | 262 | Cronograma Gantt_7 | 2024-09-11 | 2024-11-14 | 2024-09-11 | 2024-09-16 | 2024-11-19 | 2024-09-16 | 125 | 125 |
| 000126 |  | Limpieza de terreno manual | 11d | 2024-09-16 | 2024-09-27 | 000125 | 64d | 0d | 4.2.6.4 | 263 | Cronograma Gantt_7 | 2024-09-16 | 2024-11-19 | 2024-09-16 | 2024-09-27 | 2024-11-30 | 2024-09-27 | 126 | 126 |
| 000127 |  | Excavaciones no clasificada para estructuras | 3d | 2024-09-27 | 2024-09-30 | 000126 | 81d | 0d | 4.2.6.5 | 264 | Cronograma Gantt_7 | 2024-09-27 | 2024-12-17 | 2024-09-27 | 2024-09-30 | 2024-12-20 | 2024-09-30 | 127 | 127 |
| 000128 |  | Excavacion no clasificada de zanja | 2d | 2024-09-27 | 2024-09-29 | 000126 | 64d | 0d | 4.2.6.6 | 265 | Cronograma Gantt_7 | 2024-09-27 | 2024-11-30 | 2024-09-27 | 2024-09-29 | 2024-12-02 | 2024-09-29 | 128 | 128 |
| 000129 |  | Relleno estructural | 6d | 2024-09-29 | 2024-10-05 | 000128 | 76d | 0d | 4.2.6.7 | 266 | Cronograma Gantt_7 | 2024-09-29 | 2024-12-14 | 2024-09-29 | 2024-10-05 | 2024-12-20 | 2024-10-05 | 129 | 129 |
| 000132 |  | Concreto de Nivelacion (f'c=100 kg/cm2) | 1d | 2024-09-29 | 2024-09-30 | 000128 | 64d | 0d | 4.2.6.10 | 269 | Cronograma Gantt_7 | 2024-09-29 | 2024-12-02 | 2024-09-29 | 2024-09-30 | 2024-12-03 | 2024-09-30 | 132 | 132 |
| 000133 |  | Concreto Clase C (f'c=280 kg/cm2) Premezclado - Cimientos reforzados | 1d | 2024-09-30 | 2024-10-01 | 000132 | 64d | 0d | 4.2.6.11 | 271 | Cronograma Gantt_7 | 2024-09-30 | 2024-12-03 | 2024-09-30 | 2024-10-01 | 2024-12-04 | 2024-10-01 | 133 | 133 |
| 000137 |  | Acero de refuerzo f'y=4200kg/cm2 | 11d | 2024-09-30 | 2024-10-11 | 000127 | 81d |  | 4.2.6.15 | 275 | Cronograma Gantt_7 | 2024-09-30 | 2024-12-20 | 2024-09-30 | 2024-10-11 | 2024-12-31 | 2024-10-11 | 137 | 137 |
| 000130 |  | Suministro de roca (Alcantarillas) | 1d | 2024-10-05 | 2024-10-06 | 000129 | 76d | 0d | 4.2.6.8 | 267 | Cronograma Gantt_7 | 2024-10-05 | 2024-12-20 | 2024-10-05 | 2024-10-06 | 2024-12-21 | 2024-10-06 | 130 | 130 |
| 000135 |  | Encofrado y Desencofrado Caravista | 4d | 2024-10-05 | 2024-10-09 | 000133 FS+4d | 64d | 0d | 4.2.6.13 | 273 | Cronograma Gantt_7 | 2024-10-05 | 2024-12-08 | 2024-10-05 | 2024-10-09 | 2024-12-12 | 2024-10-09 | 135 | 135 |
| 000131 |  | Colocación de roca en uña (Alcantarillas) | 1d | 2024-10-06 | 2024-10-07 | 000130 | 85d |  | 4.2.6.9 | 268 | Cronograma Gantt_7 | 2024-10-06 | 2024-12-30 | 2024-10-06 | 2024-10-07 | 2024-12-31 | 2024-10-07 | 131 | 131 |
| 000136 |  | Encofrado y Desencofrado Cara Oculta | 10d | 2024-10-06 | 2024-10-16 | 000133 FS+5d | 75d | 0d | 4.2.6.14 | 274 | Cronograma Gantt_7 | 2024-10-06 | 2024-12-20 | 2024-10-06 | 2024-10-16 | 2024-12-30 | 2024-10-16 | 136 | 136 |
| 000138 |  | Emboquillado de piedra e=0.20m | 6d | 2024-10-06 | 2024-10-12 | 000130 | 76d | 0d | 4.2.6.16 | 276 | Cronograma Gantt_7 | 2024-10-06 | 2024-12-21 | 2024-10-06 | 2024-10-12 | 2024-12-27 | 2024-10-12 | 138 | 138 |
| 000134 |  | Concreto Clase C (f'c=280 kg/cm2) Premezclado - Muros de contencion | 2d | 2024-10-09 | 2024-10-11 | 000135 | 64d | 0d | 4.2.6.12 | 272 | Cronograma Gantt_7 | 2024-10-09 | 2024-12-12 | 2024-10-09 | 2024-10-11 | 2024-12-14 | 2024-10-11 | 134 | 134 |
| 000144 |  | Pintura bituminosa | 4d | 2024-10-11 | 2024-10-15 | 000134 | 77d |  | 4.2.6.22 | 285 | Cronograma Gantt_7 | 2024-10-11 | 2024-12-27 | 2024-10-11 | 2024-10-15 | 2024-12-31 | 2024-10-15 | 144 | 144 |
| 000145 |  | Suministro e Instalación de geotextil | 1d | 2024-10-11 | 2024-10-12 | 000134 | 80d |  | 4.2.6.23 | 286 | Cronograma Gantt_7 | 2024-10-11 | 2024-12-30 | 2024-10-11 | 2024-10-12 | 2024-12-31 | 2024-10-12 | 145 | 145 |
| 000139 |  | Cama de arena e=0.20m | 1d | 2024-10-12 | 2024-10-13 | 000138 | 76d | 0d | 4.2.6.17 | 279 | Cronograma Gantt_7 | 2024-10-12 | 2024-12-27 | 2024-10-12 | 2024-10-13 | 2024-12-28 | 2024-10-13 | 139 | 139 |
| 000140 |  | Tubería HDPE Corrugada Ø=900mm (Suministro e instalación) | 3d | 2024-10-13 | 2024-10-16 | 000139 | 76d |  | 4.2.6.18 | 280 | Cronograma Gantt_7 | 2024-10-13 | 2024-12-28 | 2024-10-13 | 2024-10-16 | 2024-12-31 | 2024-10-16 | 140 | 140 |
| 000141 |  | Compuerta metálica tipo tarjeta 1.00x1.00m (Suministro e instalacion) | 5d | 2024-10-13 | 2024-10-18 | 000134 FS+2d | 74d |  | 4.2.6.19 | 282 | Cronograma Gantt_7 | 2024-10-13 | 2024-12-26 | 2024-10-13 | 2024-10-18 | 2024-12-31 | 2024-10-18 | 141 | 141 |
| 000142 |  | Sello en juntas | 2d | 2024-10-16 | 2024-10-18 | 000134 FS+5d | 64d | 0d | 4.2.6.20 | 283 | Cronograma Gantt_7 | 2024-10-16 | 2024-12-19 | 2024-10-16 | 2024-10-18 | 2024-12-21 | 2024-10-18 | 142 | 142 |
| 000143 |  | Waterstop (anillos de estanqueidad) | 1d | 2024-10-16 | 2024-10-17 | 000136 | 75d |  | 4.2.6.21 | 284 | Cronograma Gantt_7 | 2024-10-16 | 2024-12-30 | 2024-10-16 | 2024-10-17 | 2024-12-31 | 2024-10-17 | 143 | 143 |
| 000146 |  | Baranda metálica (suministro e instalación) | 5d | 2024-10-18 | 2024-10-23 | 000142 | 64d | 0d | 4.2.6.24 | 287 | Cronograma Gantt_7 | 2024-10-18 | 2024-12-21 | 2024-10-18 | 2024-10-23 | 2024-12-26 | 2024-10-23 | 146 | 146 |
| 000147 |  | Rejilla metálica de 2.8mx1.50m (Suministro e instalación) | 5d | 2024-10-23 | 2024-10-28 | 000146 | 64d |  | 4.2.6.25 | 288 | Cronograma Gantt_7 | 2024-10-23 | 2024-12-26 | 2024-10-23 | 2024-10-28 | 2024-12-31 | 2024-10-28 | 147 | 147 |

| ID | WBS | Activity | Duration | Start | Finish | Predecessors | Total float | Free float | MSP Outline Number | MSP Unique ID | MSP Project Name | Imported Early Start | Imported Late Start | Imported Start | Imported Early Finish | Imported Late Finish | Imported Finish | MSP ID | MSP Task Order |
| --- | --- | --- | --- | --- | --- | --- | --- | --- | --- | --- | --- | --- | --- | --- | --- | --- | --- | --- | --- |
|  | 000148 | **DI-PR-42-0-I** |  | 2024-08-31 | 2024-11-08 |  |  |  |  |  |  |  |  |  |  |  |  |  |  |
|  | 000149 | **Excavaciones** |  | 2024-08-31 | 2024-09-05 |  |  |  |  |  |  |  |  |  |  |  |  |  |  |
| 000150 |  | Desbroce | 1d | 2024-08-31 | 2024-09-01 | 000009 | 53d | 0d | 4.3.1.1 | 309 | Cronograma Gantt_7 | 2024-08-31 | 2024-10-23 | 2024-08-31 | 2024-09-01 | 2024-10-24 | 2024-09-01 | 150 | 150 |
| 000151 |  | Excavacion de Cimentacion | 1d | 2024-09-01 | 2024-09-02 | 000150 | 53d | 0d | 4.3.1.2 | 311 | Cronograma Gantt_7 | 2024-09-01 | 2024-10-24 | 2024-09-01 | 2024-09-02 | 2024-10-25 | 2024-09-02 | 151 | 151 |
| 000153 |  | Conformacion de Material Excedente en DMO | 1d | 2024-09-03 | 2024-09-04 | 000159 | 118d | 65d | 4.3.1.4 | 315 | Cronograma Gantt_7 | 2024-09-03 | 2024-12-30 | 2024-09-03 | 2024-09-04 | 2024-12-31 | 2024-09-04 | 153 | 153 |
| 000152 |  | Conformacion de Material Excedente en DME | 1d | 2024-09-04 | 2024-09-05 | 000161 | 117d | 64d | 4.3.1.3 | 314 | Cronograma Gantt_7 | 2024-09-04 | 2024-12-30 | 2024-09-04 | 2024-09-05 | 2024-12-31 | 2024-09-05 | 152 | 152 |
|  | 000154 | **Colocacion de Roca** |  | 2024-09-06 | 2024-10-11 |  |  |  |  |  |  |  |  |  |  |  |  |  |  |
| 000155 |  | Proteccion de Talud con Colchon Reno 6m Largo x e=0.30cm | 1d | 2024-09-06 | 2024-09-07 | 000151 FS+4d | 81d | 0d | 4.3.2.1 | 334 | Cronograma Gantt_7 | 2024-09-06 | 2024-11-26 | 2024-09-06 | 2024-09-07 | 2024-11-27 | 2024-09-07 | 155 | 155 |
| 000156 |  | Malla Gavion de 1m x 1m x 5m | 34d | 2024-09-07 | 2024-10-11 | 000155 | 81d | 28d | 4.3.2.2 | 335 | Cronograma Gantt_7 | 2024-09-07 | 2024-11-27 | 2024-09-07 | 2024-10-11 | 2024-12-31 | 2024-10-11 | 156 | 156 |
|  | 000157 | **Transportes** |  | 2024-09-01 | 2024-09-04 |  |  |  |  |  |  |  |  |  |  |  |  |  |  |
| 000158 |  | Transporte de Material Organico (a DMO) D<=1km | 1d | 2024-09-01 | 2024-09-02 | 000150 | 118d | 0d | 4.3.3.1 | 342 | Cronograma Gantt_7 | 2024-09-01 | 2024-12-28 | 2024-09-01 | 2024-09-02 | 2024-12-29 | 2024-09-02 | 158 | 158 |
| 000159 |  | Transporte de Material Organico (a DMO) D>1km | 2d | 2024-09-01 | 2024-09-03 | 000158 SS | 118d | 0d | 4.3.3.2 | 343 | Cronograma Gantt_7 | 2024-09-01 | 2024-12-28 | 2024-09-01 | 2024-09-03 | 2024-12-30 | 2024-09-03 | 159 | 159 |
| 000160 |  | Transporte de Material Excedente D<=1km | 1d | 2024-09-02 | 2024-09-03 | 000151 | 117d | 0d | 4.3.3.3 | 344 | Cronograma Gantt_7 | 2024-09-02 | 2024-12-28 | 2024-09-02 | 2024-09-03 | 2024-12-29 | 2024-09-03 | 160 | 160 |
| 000161 |  | Transporte de Material Excedente D>1km | 2d | 2024-09-02 | 2024-09-04 | 000160 SS | 117d | 0d | 4.3.3.4 | 345 | Cronograma Gantt_7 | 2024-09-02 | 2024-12-28 | 2024-09-02 | 2024-09-04 | 2024-12-30 | 2024-09-04 | 161 | 161 |
|  | 000162 | **Obras Civiles** |  | 2024-09-02 | 2024-11-08 |  |  |  |  |  |  |  |  |  |  |  |  |  |  |
| 000163 |  | Concreto de Nivelacion (f'c=100 kg/cm2) | 1d | 2024-09-02 | 2024-09-03 | 000151 | 53d | 0d | 4.3.4.1 | 389 | Cronograma Gantt_7 | 2024-09-02 | 2024-10-25 | 2024-09-02 | 2024-09-03 | 2024-10-26 | 2024-09-03 | 163 | 163 |
| 000168 |  | Acero de refuerzo f'y=4200kg/cm2 | 17d | 2024-09-03 | 2024-09-20 | 000163 | 53d | 0d | 4.3.4.6 | 394 | Cronograma Gantt_7 | 2024-09-03 | 2024-10-26 | 2024-09-03 | 2024-09-20 | 2024-11-12 | 2024-09-20 | 168 | 168 |
| 000164 |  | Concreto Clase C (f'c=280 kg/cm2) Premezclado - Cimientos reforzados | 6d | 2024-09-05 | 2024-09-11 | 000168 SS+2d | 53d | 0d | 4.3.4.2 | 390 | Cronograma Gantt_7 | 2024-09-05 | 2024-10-28 | 2024-09-05 | 2024-09-11 | 2024-11-03 | 2024-09-11 | 164 | 164 |
| 000166 |  | Encofrado y Desencofrado Caravista | 23d | 2024-09-15 | 2024-10-08 | 000164 FS+4d | 53d | 0d | 4.3.4.4 | 392 | Cronograma Gantt_7 | 2024-09-15 | 2024-11-07 | 2024-09-15 | 2024-10-08 | 2024-11-30 | 2024-10-08 | 166 | 166 |
| 000167 |  | Encofrado y Desencofrado Cara Oculta | 6d | 2024-09-16 | 2024-09-22 | 000164 FS+5d | 69d | 16d | 4.3.4.5 | 393 | Cronograma Gantt_7 | 2024-09-16 | 2024-11-24 | 2024-09-16 | 2024-09-22 | 2024-11-30 | 2024-09-22 | 167 | 167 |
| 000165 |  | Concreto Clase C (f'c=280 kg/cm2) Premezclado - Muros de contencion | 7d | 2024-10-08 | 2024-10-15 | 000167, 000166 | 53d | 0d | 4.3.4.3 | 391 | Cronograma Gantt_7 | 2024-10-08 | 2024-11-30 | 2024-10-08 | 2024-10-15 | 2024-12-07 | 2024-10-15 | 165 | 165 |
| 000169 |  | Junta de dilatación | 2d | 2024-10-21 | 2024-10-23 | 000165 FS+6d | 53d | 0d | 4.3.4.7 | 395 | Cronograma Gantt_7 | 2024-10-21 | 2024-12-13 | 2024-10-21 | 2024-10-23 | 2024-12-15 | 2024-10-23 | 169 | 169 |
| 000170 |  | Pintura bituminosa | 16d | 2024-10-23 | 2024-11-08 | 000169 | 53d | 0d | 4.3.4.8 | 396 | Cronograma Gantt_7 | 2024-10-23 | 2024-12-15 | 2024-10-23 | 2024-11-08 | 2024-12-31 | 2024-11-08 | 170 | 170 |
|  | 000171 | **DI-PR-42-5-I** |  | 2024-09-01 | 2024-10-12 |  |  |  |  |  |  |  |  |  |  |  |  |  |  |
|  | 000172 | **Excavaciones** |  | 2024-09-01 | 2024-09-18 |  |  |  |  |  |  |  |  |  |  |  |  |  |  |
| 000173 |  | Desbroce | 1d | 2024-09-01 | 2024-09-02 | 000011 | 80d | 0d | 4.4.1.1 | 404 | Cronograma Gantt_7 | 2024-09-01 | 2024-11-20 | 2024-09-01 | 2024-09-02 | 2024-11-21 | 2024-09-02 | 173 | 173 |
| 000174 |  | Excavacion de Cimentacion | 3d | 2024-09-02 | 2024-09-05 | 000173 | 80d | 0d | 4.4.1.2 | 406 | Cronograma Gantt_7 | 2024-09-02 | 2024-11-21 | 2024-09-02 | 2024-09-05 | 2024-11-24 | 2024-09-05 | 174 | 174 |
| 000176 |  | Conformacion de Material Excedente en DMO | 1d | 2024-09-09 | 2024-09-10 | 000183 | 112d | 32d | 4.4.1.4 | 410 | Cronograma Gantt_7 | 2024-09-09 | 2024-12-30 | 2024-09-09 | 2024-09-10 | 2024-12-31 | 2024-09-10 | 176 | 176 |
| 000175 |  | Conformacion de Material Excedente en DME | 1d | 2024-09-17 | 2024-09-18 | 000185 | 104d | 24d | 4.4.1.3 | 409 | Cronograma Gantt_7 | 2024-09-17 | 2024-12-30 | 2024-09-17 | 2024-09-18 | 2024-12-31 | 2024-09-18 | 175 | 175 |

| ID | WBS | Activity | Duration | Start | Finish | Predecessors | Total float | Free float | MSP Outline Number | MSP Unique ID | MSP Project Name | Imported Early Start | Imported Late Start | Imported Start | Imported Early Finish | Imported Late Finish | Imported Finish | MSP ID | MSP Task Order |
| --- | --- | --- | --- | --- | --- | --- | --- | --- | --- | --- | --- | --- | --- | --- | --- | --- | --- | --- | --- |
|  | 000177 | **Rellenos** |  | 2024-09-23 | 2024-10-09 |  |  |  |  |  |  |  |  |  |  |  |  |  |  |
| 000178 |  | Relleno estructural | 16d | 2024-09-23 | 2024-10-09 | 000191 | 80d | 0d | 4.4.2.1 | 420 | Cronograma Gantt_7 | 2024-09-23 | 2024-12-12 | 2024-09-23 | 2024-10-09 | 2024-12-28 | 2024-10-09 | 178 | 178 |
|  | 000179 | **Colocacion de Roca** |  | 2024-10-09 | 2024-10-12 |  |  |  |  |  |  |  |  |  |  |  |  |  |  |
| 000180 |  | Colocacion de Roca en Talud | 3d | 2024-10-09 | 2024-10-12 | 000187, 000178 | 80d | 0d | 4.4.3.1 | 427 | Cronograma Gantt_7 | 2024-10-09 | 2024-12-28 | 2024-10-09 | 2024-10-12 | 2024-12-31 | 2024-10-12 | 180 | 180 |
|  | 000181 | **Transportes** |  | 2024-09-02 | 2024-09-25 |  |  |  |  |  |  |  |  |  |  |  |  |  |  |
| 000182 |  | Transporte de Material Organico (a DMO) D<=1km | 2d | 2024-09-02 | 2024-09-04 | 000173 | 112d | 0d | 4.4.4.1 | 437 | Cronograma Gantt_7 | 2024-09-02 | 2024-12-23 | 2024-09-02 | 2024-09-04 | 2024-12-25 | 2024-09-04 | 182 | 182 |
| 000183 |  | Transporte de Material Organico (a DMO) D>1km | 7d | 2024-09-02 | 2024-09-09 | 000182 SS | 112d | 0d | 4.4.4.2 | 438 | Cronograma Gantt_7 | 2024-09-02 | 2024-12-23 | 2024-09-02 | 2024-09-09 | 2024-12-30 | 2024-09-09 | 183 | 183 |
| 000184 |  | Transporte de Material Excedente D<=1km | 4d | 2024-09-05 | 2024-09-09 | 000174 | 80d | 0d | 4.4.4.3 | 439 | Cronograma Gantt_7 | 2024-09-05 | 2024-11-24 | 2024-09-05 | 2024-09-09 | 2024-11-28 | 2024-09-09 | 184 | 184 |
| 000185 |  | Transporte de Material Excedente D>1km | 12d | 2024-09-05 | 2024-09-17 | 000184 SS | 80d | 0d | 4.4.4.4 | 440 | Cronograma Gantt_7 | 2024-09-05 | 2024-11-24 | 2024-09-05 | 2024-09-17 | 2024-12-06 | 2024-09-17 | 185 | 185 |
| 000186 |  | Transporte de Material de Prestamo (Afirmado) D<=1km | 2d | 2024-09-17 | 2024-09-19 | 000185 | 80d | 0d | 4.4.4.5 | 441 | Cronograma Gantt_7 | 2024-09-17 | 2024-12-06 | 2024-09-17 | 2024-09-19 | 2024-12-08 | 2024-09-19 | 186 | 186 |
| 000187 |  | Transporte de Material de Prestamo (Afirmado) D>1km | 1d | 2024-09-17 | 2024-09-18 | 000186 SS | 80d | 0d | 4.4.4.6 | 442 | Cronograma Gantt_7 | 2024-09-17 | 2024-12-06 | 2024-09-17 | 2024-09-18 | 2024-12-07 | 2024-09-18 | 187 | 187 |
| 000190 |  | Transporte de Material de Prestamo Cantera de Rio (Cuerpo de Terraplen) D<=1km | 3d | 2024-09-18 | 2024-09-21 | 000187 | 80d | 0d | 4.4.4.9 | 445 | Cronograma Gantt_7 | 2024-09-18 | 2024-12-07 | 2024-09-18 | 2024-09-21 | 2024-12-10 | 2024-09-21 | 190 | 190 |
| 000191 |  | Transporte de Material de Prestamo Cantera de Rio (Cuerpo de Terraplen) D>1km | 5d | 2024-09-18 | 2024-09-23 | 000190 SS | 80d | 0d | 4.4.4.10 | 446 | Cronograma Gantt_7 | 2024-09-18 | 2024-12-07 | 2024-09-18 | 2024-09-23 | 2024-12-12 | 2024-09-23 | 191 | 191 |
| 000188 |  | Transporte de Roca D<=1km | 2d | 2024-09-23 | 2024-09-25 | 000191 | 413d | 0d | 4.4.4.7 | 443 | Cronograma Gantt_7 | 2024-09-23 | 2025-11-10 | 2024-09-23 | 2024-09-25 | 2025-11-12 | 2024-09-25 | 188 | 188 |
| 000189 |  | Transporte de Roca D>1km | 1d | 2024-09-23 | 2024-09-24 | 000188 SS | 414d |  | 4.4.4.8 | 444 | Cronograma Gantt_7 | 2024-09-23 | 2025-11-11 | 2024-09-23 | 2024-09-24 | 2025-11-12 | 2024-09-24 | 189 | 189 |
|  | 000192 | **Obras Civiles (Interferencias)** |  | 2024-09-05 | 2024-09-27 |  |  |  |  |  |  |  |  |  |  |  |  |  |  |
| 000193 |  | Trazo y replanteo de interferencia | 1d | 2024-09-05 | 2024-09-06 | 000174 | 95d | 0d | 4.4.5.1 | 450 | Cronograma Gantt_7 | 2024-09-05 | 2024-12-09 | 2024-09-05 | 2024-09-06 | 2024-12-10 | 2024-09-06 | 193 | 193 |
| 000194 |  | Desvío provisional con tubería | 1d | 2024-09-06 | 2024-09-07 | 000193 | 95d | 0d | 4.4.5.2 | 451 | Cronograma Gantt_7 | 2024-09-06 | 2024-12-10 | 2024-09-06 | 2024-09-07 | 2024-12-11 | 2024-09-07 | 194 | 194 |
| 000195 |  | Limpieza de terreno manual | 1d | 2024-09-07 | 2024-09-08 | 000194 | 95d | 0d | 4.4.5.3 | 453 | Cronograma Gantt_7 | 2024-09-07 | 2024-12-11 | 2024-09-07 | 2024-09-08 | 2024-12-12 | 2024-09-08 | 195 | 195 |
| 000196 |  | Excavaciones no clasificada para estructuras | 1d | 2024-09-08 | 2024-09-09 | 000195 | 95d | 0d | 4.4.5.4 | 454 | Cronograma Gantt_7 | 2024-09-08 | 2024-12-12 | 2024-09-08 | 2024-09-09 | 2024-12-13 | 2024-09-09 | 196 | 196 |
| 000197 |  | Concreto de Nivelacion (f'c=100 kg/cm2) | 1d | 2024-09-09 | 2024-09-10 | 000196 | 95d | 0d | 4.4.5.5 | 459 | Cronograma Gantt_7 | 2024-09-09 | 2024-12-13 | 2024-09-09 | 2024-09-10 | 2024-12-14 | 2024-09-10 | 197 | 197 |
| 000202 |  | Acero de refuerzo f'y=4200kg/cm2 | 3d | 2024-09-10 | 2024-09-13 | 000197 | 95d | 0d | 4.4.5.10 | 465 | Cronograma Gantt_7 | 2024-09-10 | 2024-12-14 | 2024-09-10 | 2024-09-13 | 2024-12-17 | 2024-09-13 | 202 | 202 |
| 000198 |  | Concreto Clase C (f'c=280 kg/cm2) Premezclado - Cimientos reforzados | 1d | 2024-09-13 | 2024-09-14 | 000202 | 95d | 0d | 4.4.5.6 | 461 | Cronograma Gantt_7 | 2024-09-13 | 2024-12-17 | 2024-09-13 | 2024-09-14 | 2024-12-18 | 2024-09-14 | 198 | 198 |
| 000201 |  | Encofrado y Desencofrado Cara Oculta | 2d | 2024-09-14 | 2024-09-16 | 000198 | 95d | 0d | 4.4.5.9 | 464 | Cronograma Gantt_7 | 2024-09-14 | 2024-12-18 | 2024-09-14 | 2024-09-16 | 2024-12-20 | 2024-09-16 | 201 | 201 |
| 000200 |  | Encofrado y Desencofrado Caravista | 2d | 2024-09-16 | 2024-09-18 | 000201 | 95d | 0d | 4.4.5.8 | 463 | Cronograma Gantt_7 | 2024-09-16 | 2024-12-20 | 2024-09-16 | 2024-09-18 | 2024-12-22 | 2024-09-18 | 200 | 200 |
| 000199 |  | Concreto Clase C (f'c=280 kg/cm2) Premezclado - Muros de contencion | 1d | 2024-09-18 | 2024-09-19 | 000200 | 95d | 0d | 4.4.5.7 | 462 | Cronograma Gantt_7 | 2024-09-18 | 2024-12-22 | 2024-09-18 | 2024-09-19 | 2024-12-23 | 2024-09-19 | 199 | 199 |
| 000203 |  | Emboquillado de piedra e=0.30m | 2d | 2024-09-21 | 2024-09-23 | 000199 FS+2d | 99d | 19d | 4.4.5.11 | 467 | Cronograma Gantt_7 | 2024-09-21 | 2024-12-29 | 2024-09-21 | 2024-09-23 | 2024-12-31 | 2024-09-23 | 203 | 203 |
| 000204 |  | Sello en juntas | 1d | 2024-09-21 | 2024-09-22 | 000199 FS+2d | 95d | 0d | 4.4.5.12 | 473 | Cronograma Gantt_7 | 2024-09-21 | 2024-12-25 | 2024-09-21 | 2024-09-22 | 2024-12-26 | 2024-09-22 | 204 | 204 |
| 000206 |  | Compuerta metálica tipo tarjeta 1.40x1.40 m (Suministro e instalacion) | 5d | 2024-09-22 | 2024-09-27 | 000204 | 95d | 15d | 4.4.5.14 | 479 | Cronograma Gantt_7 | 2024-09-22 | 2024-12-26 | 2024-09-22 | 2024-09-27 | 2024-12-31 | 2024-09-27 | 206 | 206 |
| 000205 |  | Pintura bituminosa | 1d | 2024-09-23 | 2024-09-24 | 000199 FS+4d | 98d | 18d | 4.4.5.13 | 475 | Cronograma Gantt_7 | 2024-09-23 | 2024-12-30 | 2024-09-23 | 2024-09-24 | 2024-12-31 | 2024-09-24 | 205 | 205 |

| ID | WBS | Activity | Duration | Start | Finish | Predecessors | Total float | Free float | MSP Outline Number | MSP Unique ID | MSP Project Name | Imported Early Start | Imported Late Start | Imported Start | Imported Early Finish | Imported Late Finish | Imported Finish | MSP ID | MSP Task Order |
| --- | --- | --- | --- | --- | --- | --- | --- | --- | --- | --- | --- | --- | --- | --- | --- | --- | --- | --- | --- |
|  | 000207 | **Medio Ambiente** |  | 2024-07-26 | 2024-09-24 |  |  |  |  |  |  |  |  |  |  |  |  |  |  |
|  | 000208 | **Mitigación Ambiental** |  | 2024-07-26 | 2024-09-24 |  |  |  |  |  |  |  |  |  |  |  |  |  |  |
| 000209 |  | Rescate camaron | 60d | 2024-07-26 | 2024-09-24 | 000004 | 98d |  | 4.5.1.1 | 1272 | Cronograma Gantt_7 | 2024-07-26 | 2024-11-01 | 2024-07-26 | 2024-09-24 | 2024-12-31 | 2024-09-24 | 209 | 209 |
|  | 000210 | **Otros** |  | 2024-08-25 | 2024-12-31 |  |  |  |  |  |  |  |  |  |  |  |  |  |  |
| 000211 |  | Retiro y reubicacion de postes de canotaje | 128d | 2024-08-25 | 2024-12-31 | 000004 FS+30d | 0d |  | 4.6.1 | 1275 | Cronograma Gantt_7 | 2024-08-25 | 2024-08-25 | 2024-08-25 | 2024-12-31 | 2024-12-31 | 2024-12-31 | 211 | 211 |
|  | 000212 | **SEGUNDA ETAPA** |  | 2024-06-13 | 2025-11-12 |  |  |  |  |  |  |  |  |  |  |  |  |  |  |
| 000508 |  | Descolmatación | 30d | 2025-10-13 | 2025-11-12 | 000478 | 0d |  | 5.7 | 1297 | Cronograma Gantt_7 | 2025-10-13 | 2025-10-13 | 2025-10-13 | 2025-11-12 | 2025-11-12 | 2025-11-12 | 508 | 508 |
|  | 000213 | **DI-PR-53-I** |  | 2025-05-01 | 2025-08-06 |  |  |  |  |  |  |  |  |  |  |  |  |  |  |
|  | 000214 | **Excavaciones** |  | 2025-05-01 | 2025-05-30 |  |  |  |  |  |  |  |  |  |  |  |  |  |  |
| 000215 |  | Desbroce | 2d | 2025-05-01 | 2025-05-03 | 000016 | 0d |  | 5.1.1.1 | 502 | Cronograma Gantt_7 | 2025-05-01 | 2025-05-01 | 2025-05-01 | 2025-05-03 | 2025-05-03 | 2025-05-03 | 215 | 215 |
| 000216 |  | Remocion de Dique Existente | 1d | 2025-05-03 | 2025-05-04 | 000215 | 0d |  | 5.1.1.2 | 503 | Cronograma Gantt_7 | 2025-05-03 | 2025-05-03 | 2025-05-03 | 2025-05-04 | 2025-05-04 | 2025-05-04 | 216 | 216 |
| 000217 |  | Excavacion de Cimentacion | 20d | 2025-05-04 | 2025-05-24 | 000216 | 0d |  | 5.1.1.3 | 504 | Cronograma Gantt_7 | 2025-05-04 | 2025-05-04 | 2025-05-04 | 2025-05-24 | 2025-05-24 | 2025-05-24 | 217 | 217 |
| 000218 |  | Perfilado y Conformacion de Plataforma de Fundacion | 4d | 2025-05-06 | 2025-05-10 | 000217 SS+2d | 186d | 88d | 5.1.1.4 | 505 | Cronograma Gantt_7 | 2025-05-06 | 2025-11-08 | 2025-05-06 | 2025-05-10 | 2025-11-12 | 2025-05-10 | 218 | 218 |
| 000219 |  | Excavacion de Uña | 12d | 2025-05-06 | 2025-05-18 | 000217 SS+2d | 178d | 80d | 5.1.1.5 | 506 | Cronograma Gantt_7 | 2025-05-06 | 2025-10-31 | 2025-05-06 | 2025-05-18 | 2025-11-12 | 2025-05-18 | 219 | 219 |
| 000222 |  | Excavacion Localizada - Sobreexcavacion | 10d | 2025-05-09 | 2025-05-19 | 000216 FS+5d | 177d | 79d | 5.1.1.8 | 509 | Cronograma Gantt_7 | 2025-05-09 | 2025-11-02 | 2025-05-09 | 2025-05-19 | 2025-11-12 | 2025-05-19 | 222 | 222 |
| 000220 |  | Conformacion de Material Excedente en DME | 19d | 2025-05-11 | 2025-05-30 | 000240 FS-18d | 166d | 68d | 5.1.1.6 | 507 | Cronograma Gantt_7 | 2025-05-11 | 2025-10-24 | 2025-05-11 | 2025-05-30 | 2025-11-12 | 2025-05-30 | 220 | 220 |
| 000221 |  | Conformacion de Material Excedente en DMO | 3d | 2025-05-15 | 2025-05-18 | 000238 | 178d | 80d | 5.1.1.7 | 508 | Cronograma Gantt_7 | 2025-05-15 | 2025-11-09 | 2025-05-15 | 2025-05-18 | 2025-11-12 | 2025-05-18 | 221 | 221 |
|  | 000223 | **Rellenos** |  | 2025-06-05 | 2025-07-28 |  |  |  |  |  |  |  |  |  |  |  |  |  |  |
| 000224 |  | Relleno con Material Granular (incluye extraccion de material, zarandeo y combinado) | 9d | 2025-06-05 | 2025-06-14 | 000246 FS-8d | 151d | 53d | 5.1.2.1 | 512 | Cronograma Gantt_7 | 2025-06-05 | 2025-11-03 | 2025-06-05 | 2025-06-14 | 2025-11-12 | 2025-06-14 | 224 | 224 |
| 000227 |  | Relleno con Material Seleccionado (incluye extraccion de material, zarandeo y combinado) | 11d | 2025-06-08 | 2025-06-19 | 000246 FS-5d | 125d | 0d | 5.1.2.4 | 516 | Cronograma Gantt_7 | 2025-06-08 | 2025-10-11 | 2025-06-08 | 2025-06-19 | 2025-10-22 | 2025-06-19 | 227 | 227 |
| 000226 |  | Perfilado de Talud Dique | 2d | 2025-06-19 | 2025-06-21 | 000227 | 125d | 0d | 5.1.2.3 | 515 | Cronograma Gantt_7 | 2025-06-19 | 2025-10-22 | 2025-06-19 | 2025-06-21 | 2025-10-24 | 2025-06-21 | 226 | 226 |
| 000225 |  | Relleno Afirmado | 1d | 2025-07-09 | 2025-07-10 | 000242, 000231 | 125d | 27d | 5.1.2.2 | 514 | Cronograma Gantt_7 | 2025-07-09 | 2025-11-11 | 2025-07-09 | 2025-07-10 | 2025-11-12 | 2025-07-10 | 225 | 225 |
| 000228 |  | Grava para Drenaje | 1d | 2025-07-27 | 2025-07-28 | 000233 | 107d | 9d | 5.1.2.5 | 517 | Cronograma Gantt_7 | 2025-07-27 | 2025-11-11 | 2025-07-27 | 2025-07-28 | 2025-11-12 | 2025-07-28 | 228 | 228 |
|  | 000229 | **Geotextil** |  | 2025-06-21 | 2025-07-09 |  |  |  |  |  |  |  |  |  |  |  |  |  |  |
| 000230 |  | Instalacion de Geotextil 400gr/m2 | 17d | 2025-06-21 | 2025-07-08 | 000226 | 125d | 0d | 5.1.3.1 | 520 | Cronograma Gantt_7 | 2025-06-21 | 2025-10-24 | 2025-06-21 | 2025-07-08 | 2025-11-10 | 2025-07-08 | 230 | 230 |
| 000231 |  | Zanja de Anclaje | 13d | 2025-06-26 | 2025-07-09 | 000248, 000230 SS+5d | 125d | 0d | 5.1.3.2 | 521 | Cronograma Gantt_7 | 2025-06-26 | 2025-10-29 | 2025-06-26 | 2025-07-09 | 2025-11-11 | 2025-07-09 | 231 | 231 |

| ID | WBS | Activity | Duration | Start | Finish | Predecessors | Total float | Free float | MSP Outline Number | MSP Unique ID | MSP Project Name | Imported Early Start | Imported Late Start | Imported Start | Imported Early Finish | Imported Late Finish | Imported Finish | MSP ID | MSP Task Order |
| --- | --- | --- | --- | --- | --- | --- | --- | --- | --- | --- | --- | --- | --- | --- | --- | --- | --- | --- | --- |
|  | 000232 | **Colocacion de Roca** |  | 2025-05-04 | 2025-08-06 |  |  |  |  |  |  |  |  |  |  |  |  |  |  |
| 000235 |  | Extraccion de Rocas Reutilizables | 4d | 2025-05-04 | 2025-05-08 | 000216 | 188d | 90d | 5.1.4.3 | 526 | Cronograma Gantt_7 | 2025-05-04 | 2025-11-08 | 2025-05-04 | 2025-05-08 | 2025-11-12 | 2025-05-08 | 235 | 235 |
| 000233 |  | Colocacion de Roca en Uña | 21d | 2025-07-06 | 2025-07-27 | 000244 FS-10d | 98d | 0d | 5.1.4.1 | 524 | Cronograma Gantt_7 | 2025-07-06 | 2025-10-12 | 2025-07-06 | 2025-07-27 | 2025-11-02 | 2025-07-27 | 233 | 233 |
| 000234 |  | Colocacion de Roca en Talud | 21d | 2025-07-16 | 2025-08-06 | 000233 SS+10d | 98d | 0d | 5.1.4.2 | 525 | Cronograma Gantt_7 | 2025-07-16 | 2025-10-22 | 2025-07-16 | 2025-08-06 | 2025-11-12 | 2025-08-06 | 234 | 234 |
|  | 000236 | **Transportes** |  | 2025-05-03 | 2025-07-16 |  |  |  |  |  |  |  |  |  |  |  |  |  |  |
| 000237 |  | Transporte de Material Organico (a DMO) D<=1km | 4d | 2025-05-03 | 2025-05-07 | 000215 | 178d | 0d | 5.1.5.1 | 535 | Cronograma Gantt_7 | 2025-05-03 | 2025-10-28 | 2025-05-03 | 2025-05-07 | 2025-11-01 | 2025-05-07 | 237 | 237 |
| 000238 |  | Transporte de Material Organico (a DMO) D>1km | 12d | 2025-05-03 | 2025-05-15 | 000237 SS | 178d | 0d | 5.1.5.2 | 536 | Cronograma Gantt_7 | 2025-05-03 | 2025-10-28 | 2025-05-03 | 2025-05-15 | 2025-11-09 | 2025-05-15 | 238 | 238 |
| 000239 |  | Transporte de Material Excedente D<=1km | 13d | 2025-05-09 | 2025-05-22 | 000217 SS+5d | 166d | 0d | 5.1.5.3 | 537 | Cronograma Gantt_7 | 2025-05-09 | 2025-10-22 | 2025-05-09 | 2025-05-22 | 2025-11-04 | 2025-05-22 | 239 | 239 |
| 000240 |  | Transporte de Material Excedente D>1km | 20d | 2025-05-09 | 2025-05-29 | 000239 SS | 166d | 0d | 5.1.5.4 | 538 | Cronograma Gantt_7 | 2025-05-09 | 2025-10-22 | 2025-05-09 | 2025-05-29 | 2025-11-11 | 2025-05-29 | 240 | 240 |
| 000245 |  | Transporte de Material de Prestamo Cantera de Rio (Cuerpo de Terraplen) D<=1km | 15d | 2025-05-14 | 2025-05-29 | 000217 SS+10d | 98d | 0d | 5.1.5.9 | 543 | Cronograma Gantt_7 | 2025-05-14 | 2025-08-20 | 2025-05-14 | 2025-05-29 | 2025-09-04 | 2025-05-29 | 245 | 245 |
| 000246 |  | Transporte de Material de Prestamo Cantera de Rio (Cuerpo de Terraplen) D>1km | 30d | 2025-05-14 | 2025-06-13 | 000245 SS | 98d | 0d | 5.1.5.10 | 544 | Cronograma Gantt_7 | 2025-05-14 | 2025-08-20 | 2025-05-14 | 2025-06-13 | 2025-09-19 | 2025-06-13 | 246 | 246 |
| 000247 |  | Transporte de Material Seleccionado para Zanja D<=1km | 1d | 2025-06-13 | 2025-06-14 | 000246 | 98d | 0d | 5.1.5.11 | 545 | Cronograma Gantt_7 | 2025-06-13 | 2025-09-19 | 2025-06-13 | 2025-06-14 | 2025-09-20 | 2025-06-14 | 247 | 247 |
| 000248 |  | Transporte de Material Seleccionado para Zanja D>1km | 1d | 2025-06-13 | 2025-06-14 | 000247 SS | 98d | 0d | 5.1.5.12 | 546 | Cronograma Gantt_7 | 2025-06-13 | 2025-09-19 | 2025-06-13 | 2025-06-14 | 2025-09-20 | 2025-06-14 | 248 | 248 |
| 000241 |  | Transporte de Material de Prestamo (Afirmado) D<=1km | 3d | 2025-06-14 | 2025-06-17 | 000248 | 98d | 0d | 5.1.5.5 | 539 | Cronograma Gantt_7 | 2025-06-14 | 2025-09-20 | 2025-06-14 | 2025-06-17 | 2025-09-23 | 2025-06-17 | 241 | 241 |
| 000242 |  | Transporte de Material de Prestamo (Afirmado) D>1km | 10d | 2025-06-14 | 2025-06-24 | 000241 SS | 98d | 0d | 5.1.5.6 | 540 | Cronograma Gantt_7 | 2025-06-14 | 2025-09-20 | 2025-06-14 | 2025-06-24 | 2025-09-30 | 2025-06-24 | 242 | 242 |
| 000243 |  | Transporte de Roca D<=1km | 15d | 2025-06-24 | 2025-07-09 | 000242 | 98d | 0d | 5.1.5.7 | 541 | Cronograma Gantt_7 | 2025-06-24 | 2025-09-30 | 2025-06-24 | 2025-07-09 | 2025-10-15 | 2025-07-09 | 243 | 243 |
| 000244 |  | Transporte de Roca D>1km | 22d | 2025-06-24 | 2025-07-16 | 000243 SS | 98d | 0d | 5.1.5.8 | 542 | Cronograma Gantt_7 | 2025-06-24 | 2025-09-30 | 2025-06-24 | 2025-07-16 | 2025-10-22 | 2025-07-16 | 244 | 244 |
|  | 000249 | **Obras Civiles (Interferencias)** |  | 2025-05-03 | 2025-06-16 |  |  |  |  |  |  |  |  |  |  |  |  |  |  |
| 000250 |  | Trazo y replanteo de interferencia | 1d | 2025-05-03 | 2025-05-04 | 000215 | 89d | 0d | 5.1.6.1 | 548 | Cronograma Gantt_7 | 2025-05-03 | 2025-07-31 | 2025-05-03 | 2025-05-04 | 2025-08-01 | 2025-05-04 | 250 | 250 |
| 000253 |  | Limpieza de terreno manual | 9d | 2025-05-04 | 2025-05-13 | 000250 | 89d | 0d | 5.1.6.4 | 551 | Cronograma Gantt_7 | 2025-05-04 | 2025-08-01 | 2025-05-04 | 2025-05-13 | 2025-08-10 | 2025-05-13 | 253 | 253 |
| 000254 |  | Excavaciones no clasificada para estructuras | 1d | 2025-05-13 | 2025-05-14 | 000253 | 89d | 0d | 5.1.6.5 | 552 | Cronograma Gantt_7 | 2025-05-13 | 2025-08-10 | 2025-05-13 | 2025-05-14 | 2025-08-11 | 2025-05-14 | 254 | 254 |
| 000255 |  | Excavacion no clasificada de zanja | 4d | 2025-05-13 | 2025-05-17 | 000253 | 106d | 0d | 5.1.6.6 | 553 | Cronograma Gantt_7 | 2025-05-13 | 2025-08-27 | 2025-05-13 | 2025-05-17 | 2025-08-31 | 2025-05-17 | 255 | 255 |
| 000256 |  | Relleno estructural | 3d | 2025-05-14 | 2025-05-17 | 000254 | 89d | 0d | 5.1.6.7 | 554 | Cronograma Gantt_7 | 2025-05-14 | 2025-08-11 | 2025-05-14 | 2025-05-17 | 2025-08-14 | 2025-05-17 | 256 | 256 |
| 000251 |  | Desvío provisional con tubería | 1d | 2025-05-17 | 2025-05-18 | 000255 | 178d | 80d | 5.1.6.2 | 549 | Cronograma Gantt_7 | 2025-05-17 | 2025-11-11 | 2025-05-17 | 2025-05-18 | 2025-11-12 | 2025-05-18 | 251 | 251 |
| 000252 |  | Desvío provisional en tierras | 5d | 2025-05-17 | 2025-05-22 | 000255 | 174d | 76d | 5.1.6.3 | 550 | Cronograma Gantt_7 | 2025-05-17 | 2025-11-07 | 2025-05-17 | 2025-05-22 | 2025-11-12 | 2025-05-22 | 252 | 252 |
| 000257 |  | Suministro de roca (Alcantarillas) | 1d | 2025-05-17 | 2025-05-18 | 000256 | 177d | 0d | 5.1.6.8 | 555 | Cronograma Gantt_7 | 2025-05-17 | 2025-11-10 | 2025-05-17 | 2025-05-18 | 2025-11-11 | 2025-05-18 | 257 | 257 |
| 000259 |  | Concreto de Nivelacion (f'c=100 kg/cm2) | 2d | 2025-05-17 | 2025-05-19 | 000256 | 89d | 0d | 5.1.6.10 | 557 | Cronograma Gantt_7 | 2025-05-17 | 2025-08-14 | 2025-05-17 | 2025-05-19 | 2025-08-16 | 2025-05-19 | 259 | 259 |
| 000258 |  | Colocación de roca en uña (Alcantarillas) | 1d | 2025-05-18 | 2025-05-19 | 000257 | 177d | 79d | 5.1.6.9 | 556 | Cronograma Gantt_7 | 2025-05-18 | 2025-11-11 | 2025-05-18 | 2025-05-19 | 2025-11-12 | 2025-05-19 | 258 | 258 |
| 000264 |  | Acero de refuerzo f'y=4200kg/cm2 | 6d | 2025-05-19 | 2025-05-25 | 000259 | 89d | 0d | 5.1.6.15 | 563 | Cronograma Gantt_7 | 2025-05-19 | 2025-08-16 | 2025-05-19 | 2025-05-25 | 2025-08-22 | 2025-05-25 | 264 | 264 |
| 000260 |  | Concreto Clase C (f'c=280 kg/cm2) Premezclado - Cimientos reforzados | 1d | 2025-05-25 | 2025-05-26 | 000264 | 89d | 0d | 5.1.6.11 | 559 | Cronograma Gantt_7 | 2025-05-25 | 2025-08-22 | 2025-05-25 | 2025-05-26 | 2025-08-23 | 2025-05-26 | 260 | 260 |
| 000262 |  | Encofrado y Desencofrado Caravista | 4d | 2025-05-26 | 2025-05-30 | 000260 | 166d | 68d | 5.1.6.13 | 561 | Cronograma Gantt_7 | 2025-05-26 | 2025-11-08 | 2025-05-26 | 2025-05-30 | 2025-11-12 | 2025-05-30 | 262 | 262 |
| 000263 |  | Encofrado y Desencofrado Cara Oculta | 6d | 2025-05-26 | 2025-06-01 | 000260 | 89d | 0d | 5.1.6.14 | 562 | Cronograma Gantt_7 | 2025-05-26 | 2025-08-23 | 2025-05-26 | 2025-06-01 | 2025-08-29 | 2025-06-01 | 263 | 263 |
| 000261 |  | Concreto Clase C (f'c=280 kg/cm2) Premezclado - Muros de contencion | 2d | 2025-06-01 | 2025-06-03 | 000263 | 89d | 0d | 5.1.6.12 | 560 | Cronograma Gantt_7 | 2025-06-01 | 2025-08-29 | 2025-06-01 | 2025-06-03 | 2025-08-31 | 2025-06-03 | 261 | 261 |
| 000265 |  | Emboquillado de piedra e=0.20m | 7d | 2025-06-03 | 2025-06-10 | 000261 | 155d | 57d | 5.1.6.16 | 564 | Cronograma Gantt_7 | 2025-06-03 | 2025-11-05 | 2025-06-03 | 2025-06-10 | 2025-11-12 | 2025-06-10 | 265 | 265 |
| 000266 |  | Cama de arena e=0.20m | 1d | 2025-06-03 | 2025-06-04 | 000261, 000255 | 89d | 0d | 5.1.6.17 | 567 | Cronograma Gantt_7 | 2025-06-03 | 2025-08-31 | 2025-06-03 | 2025-06-04 | 2025-09-01 | 2025-06-04 | 266 | 266 |
| 000269 |  | Sello en juntas | 2d | 2025-06-03 | 2025-06-05 | 000261 | 160d | 62d | 5.1.6.20 | 571 | Cronograma Gantt_7 | 2025-06-03 | 2025-11-10 | 2025-06-03 | 2025-06-05 | 2025-11-12 | 2025-06-05 | 269 | 269 |
| 000270 |  | Waterstop (anillos de estanqueidad) | 1d | 2025-06-03 | 2025-06-04 | 000261 | 161d | 63d | 5.1.6.21 | 572 | Cronograma Gantt_7 | 2025-06-03 | 2025-11-11 | 2025-06-03 | 2025-06-04 | 2025-11-12 | 2025-06-04 | 270 | 270 |
| 000267 |  | Tubería HDPE Corrugada Ø=900mm (Suministro e instalación) | 1d | 2025-06-04 | 2025-06-05 | 000266 | 89d | 0d | 5.1.6.18 | 568 | Cronograma Gantt_7 | 2025-06-04 | 2025-09-01 | 2025-06-04 | 2025-06-05 | 2025-09-02 | 2025-06-05 | 267 | 267 |
| 000272 |  | Suministro e Instalación de geotextil | 1d | 2025-06-05 | 2025-06-06 | 000267 | 89d | 0d | 5.1.6.23 | 574 | Cronograma Gantt_7 | 2025-06-05 | 2025-09-02 | 2025-06-05 | 2025-06-06 | 2025-09-03 | 2025-06-06 | 272 | 272 |
| 000268 |  | Compuertas Charnela Ø900 (Suministro e instalacion) | 5d | 2025-06-06 | 2025-06-11 | 000272 | 89d | 0d | 5.1.6.19 | 569 | Cronograma Gantt_7 | 2025-06-06 | 2025-09-03 | 2025-06-06 | 2025-06-11 | 2025-09-08 | 2025-06-11 | 268 | 268 |
| 000271 |  | Pintura bituminosa | 5d | 2025-06-11 | 2025-06-16 | 000268 | 89d | 0d | 5.1.6.22 | 573 | Cronograma Gantt_7 | 2025-06-11 | 2025-09-08 | 2025-06-11 | 2025-06-16 | 2025-09-13 | 2025-06-16 | 271 | 271 |

| ID | WBS | Activity | Duration | Start | Finish | Predecessors | Total float | Free float | MSP Outline Number | MSP Unique ID | MSP Project Name | Imported Early Start | Imported Late Start | Imported Start | Imported Early Finish | Imported Late Finish | Imported Finish | MSP ID | MSP Task Order |
| --- | --- | --- | --- | --- | --- | --- | --- | --- | --- | --- | --- | --- | --- | --- | --- | --- | --- | --- | --- |
|  | 000273 | **DI-PR-51-I** |  | 2025-05-24 | 2025-10-04 |  |  |  |  |  |  |  |  |  |  |  |  |  |  |
|  | 000274 | **Excavaciones** |  | 2025-05-24 | 2025-07-13 |  |  |  |  |  |  |  |  |  |  |  |  |  |  |
| 000275 |  | Desbroce | 3d | 2025-05-24 | 2025-05-27 | 000018 | 0d |  | 5.2.1.1 | 597 | Cronograma Gantt_7 | 2025-05-24 | 2025-05-24 | 2025-05-24 | 2025-05-27 | 2025-05-27 | 2025-05-27 | 275 | 275 |
| 000276 |  | Excavacion de Cimentacion | 19d | 2025-05-27 | 2025-06-15 | 000275 | 0d |  | 5.2.1.2 | 599 | Cronograma Gantt_7 | 2025-05-27 | 2025-05-27 | 2025-05-27 | 2025-06-15 | 2025-06-15 | 2025-06-15 | 276 | 276 |
| 000277 |  | Perfilado y Conformacion de Plataforma de Fundacion | 7d | 2025-06-01 | 2025-06-08 | 000276 SS+5d | 157d | 118d | 5.2.1.3 | 600 | Cronograma Gantt_7 | 2025-06-01 | 2025-11-05 | 2025-06-01 | 2025-06-08 | 2025-11-12 | 2025-06-08 | 277 | 277 |
| 000278 |  | Excavacion de Uña | 17d | 2025-06-01 | 2025-06-18 | 000276 SS+5d | 147d | 108d | 5.2.1.4 | 601 | Cronograma Gantt_7 | 2025-06-01 | 2025-10-26 | 2025-06-01 | 2025-06-18 | 2025-11-12 | 2025-06-18 | 278 | 278 |
| 000280 |  | Conformacion de Material Excedente en DMO | 4d | 2025-06-08 | 2025-06-12 | 000293 | 153d | 114d | 5.2.1.6 | 603 | Cronograma Gantt_7 | 2025-06-08 | 2025-11-08 | 2025-06-08 | 2025-06-12 | 2025-11-12 | 2025-06-12 | 280 | 280 |
| 000279 |  | Conformacion de Material Excedente en DME | 12d | 2025-07-01 | 2025-07-13 | 000295 FS-10d | 122d | 83d | 5.2.1.5 | 602 | Cronograma Gantt_7 | 2025-07-01 | 2025-10-31 | 2025-07-01 | 2025-07-13 | 2025-11-12 | 2025-07-13 | 279 | 279 |
|  | 000281 | **Rellenos** |  | 2025-07-27 | 2025-08-30 |  |  |  |  |  |  |  |  |  |  |  |  |  |  |
| 000283 |  | Relleno con Material Seleccionado (incluye extraccion de material, zarandeo y combinado) | 17d | 2025-07-27 | 2025-08-13 | 000301 FS-15d | 41d | 0d | 5.2.2.2 | 611 | Cronograma Gantt_7 | 2025-07-27 | 2025-09-06 | 2025-07-27 | 2025-08-13 | 2025-09-23 | 2025-08-13 | 283 | 283 |
| 000282 |  | Relleno con Material Granular (incluye extraccion de material, zarandeo y combinado) | 1d | 2025-08-29 | 2025-08-30 | 000297, 000286 | 41d | 2d | 5.2.2.1 | 607 | Cronograma Gantt_7 | 2025-08-29 | 2025-10-09 | 2025-08-29 | 2025-08-30 | 2025-10-10 | 2025-08-30 | 282 | 282 |
|  | 000284 | **Geotextil** |  | 2025-08-13 | 2025-08-29 |  |  |  |  |  |  |  |  |  |  |  |  |  |  |
| 000285 |  | Instalacion de Geotextil 400gr/m2 | 14d | 2025-08-13 | 2025-08-27 | 000303, 000283 | 41d | 0d | 5.2.3.1 | 615 | Cronograma Gantt_7 | 2025-08-13 | 2025-09-23 | 2025-08-13 | 2025-08-27 | 2025-10-07 | 2025-08-27 | 285 | 285 |
| 000286 |  | Zanja de Anclaje | 11d | 2025-08-18 | 2025-08-29 | 000285 SS+5d | 41d | 0d | 5.2.3.2 | 616 | Cronograma Gantt_7 | 2025-08-18 | 2025-09-28 | 2025-08-18 | 2025-08-29 | 2025-10-09 | 2025-08-29 | 286 | 286 |
|  | 000287 | **Colocacion de Roca** |  | 2025-09-01 | 2025-10-04 |  |  |  |  |  |  |  |  |  |  |  |  |  |  |
| 000288 |  | Colocacion de Roca en Uña | 29d | 2025-09-01 | 2025-09-30 | 000299, 000282 | 39d | 0d | 5.2.4.1 | 619 | Cronograma Gantt_7 | 2025-09-01 | 2025-10-10 | 2025-09-01 | 2025-09-30 | 2025-11-08 | 2025-09-30 | 288 | 288 |
| 000289 |  | Colocacion de Roca en Talud | 21d | 2025-09-11 | 2025-10-02 | 000288 SS+10d | 39d | 0d | 5.2.4.2 | 620 | Cronograma Gantt_7 | 2025-09-11 | 2025-10-20 | 2025-09-11 | 2025-10-02 | 2025-11-10 | 2025-10-02 | 289 | 289 |
| 000290 |  | Colocación de Roca en Corona | 8d | 2025-09-26 | 2025-10-04 | 000289 FS-6d | 39d | 0d | 5.2.4.3 | 626 | Cronograma Gantt_7 | 2025-09-26 | 2025-11-04 | 2025-09-26 | 2025-10-04 | 2025-11-12 | 2025-10-04 | 290 | 290 |
|  | 000291 | **Transportes** |  | 2025-05-27 | 2025-09-01 |  |  |  |  |  |  |  |  |  |  |  |  |  |  |
| 000292 |  | Transporte de Material Organico (a DMO) D<=1km | 7d | 2025-05-27 | 2025-06-03 | 000275 | 153d | 0d | 5.2.5.1 | 630 | Cronograma Gantt_7 | 2025-05-27 | 2025-10-27 | 2025-05-27 | 2025-06-03 | 2025-11-03 | 2025-06-03 | 292 | 292 |
| 000293 |  | Transporte de Material Organico (a DMO) D>1km | 12d | 2025-05-27 | 2025-06-08 | 000292 SS | 153d | 0d | 5.2.5.2 | 631 | Cronograma Gantt_7 | 2025-05-27 | 2025-10-27 | 2025-05-27 | 2025-06-08 | 2025-11-08 | 2025-06-08 | 293 | 293 |
| 000294 |  | Transporte de Material Excedente D<=1km | 20d | 2025-06-01 | 2025-06-21 | 000276 SS+5d | 39d | 0d | 5.2.5.3 | 632 | Cronograma Gantt_7 | 2025-06-01 | 2025-07-10 | 2025-06-01 | 2025-06-21 | 2025-07-30 | 2025-06-21 | 294 | 294 |
| 000295 |  | Transporte de Material Excedente D>1km | 40d | 2025-06-01 | 2025-07-11 | 000294 SS | 39d | 0d | 5.2.5.4 | 633 | Cronograma Gantt_7 | 2025-06-01 | 2025-07-10 | 2025-06-01 | 2025-07-11 | 2025-08-19 | 2025-07-11 | 295 | 295 |
| 000300 |  | Transporte de Material de Prestamo Cantera de Rio (Cuerpo de Terraplen) D<=1km | 28d | 2025-06-16 | 2025-07-14 | 000295 FS-25d | 39d | 0d | 5.2.5.9 | 638 | Cronograma Gantt_7 | 2025-06-16 | 2025-07-25 | 2025-06-16 | 2025-07-14 | 2025-08-22 | 2025-07-14 | 300 | 300 |
| 000301 |  | Transporte de Material de Prestamo Cantera de Rio (Cuerpo de Terraplen) D>1km | 56d | 2025-06-16 | 2025-08-11 | 000300 SS | 39d | 0d | 5.2.5.10 | 639 | Cronograma Gantt_7 | 2025-06-16 | 2025-07-25 | 2025-06-16 | 2025-08-11 | 2025-09-19 | 2025-08-11 | 301 | 301 |
| 000298 |  | Transporte de Roca D<=1km | 16d | 2025-08-01 | 2025-08-17 | 000301 FS-10d | 39d | 0d | 5.2.5.7 | 636 | Cronograma Gantt_7 | 2025-08-01 | 2025-09-09 | 2025-08-01 | 2025-08-17 | 2025-09-25 | 2025-08-17 | 298 | 298 |
| 000299 |  | Transporte de Roca D>1km | 31d | 2025-08-01 | 2025-09-01 | 000298 SS | 39d | 0d | 5.2.5.8 | 637 | Cronograma Gantt_7 | 2025-08-01 | 2025-09-09 | 2025-08-01 | 2025-09-01 | 2025-10-10 | 2025-09-01 | 299 | 299 |
| 000302 |  | Transporte de Material Seleccionado para Zanja D<=1km | 1d | 2025-08-10 | 2025-08-11 | 000301 FS-1d | 42d | 0d | 5.2.5.11 | 640 | Cronograma Gantt_7 | 2025-08-10 | 2025-09-21 | 2025-08-10 | 2025-08-11 | 2025-09-22 | 2025-08-11 | 302 | 302 |
| 000303 |  | Transporte de Material Seleccionado para Zanja D>1km | 1d | 2025-08-11 | 2025-08-12 | 000302 | 42d | 0d | 5.2.5.12 | 641 | Cronograma Gantt_7 | 2025-08-11 | 2025-09-22 | 2025-08-11 | 2025-08-12 | 2025-09-23 | 2025-08-12 | 303 | 303 |
| 000296 |  | Transporte de Material de Prestamo (Afirmado) D<=1km | 7d | 2025-08-12 | 2025-08-19 | 000303 | 46d | 0d | 5.2.5.5 | 634 | Cronograma Gantt_7 | 2025-08-12 | 2025-09-27 | 2025-08-12 | 2025-08-19 | 2025-10-04 | 2025-08-19 | 296 | 296 |
| 000297 |  | Transporte de Material de Prestamo (Afirmado) D>1km | 12d | 2025-08-12 | 2025-08-24 | 000296 SS | 46d | 5d | 5.2.5.6 | 635 | Cronograma Gantt_7 | 2025-08-12 | 2025-09-27 | 2025-08-12 | 2025-08-24 | 2025-10-09 | 2025-08-24 | 297 | 297 |

| ID | WBS | Activity | Duration | Start | Finish | Predecessors | Total float | Free float | MSP Outline Number | MSP Unique ID | MSP Project Name | Imported Early Start | Imported Late Start | Imported Start | Imported Early Finish | Imported Late Finish | Imported Finish | MSP ID | MSP Task Order |
| --- | --- | --- | --- | --- | --- | --- | --- | --- | --- | --- | --- | --- | --- | --- | --- | --- | --- | --- | --- |
|  | 000304 | **Obras Civiles (Interferencias)** |  | 2025-06-16 | 2025-08-15 |  |  |  |  |  |  |  |  |  |  |  |  |  |  |
| 000305 |  | Trazo y replanteo de interferencia | 2d | 2025-06-16 | 2025-06-18 | 000271 | 89d | 0d | 5.2.6.1 | 643 | Cronograma Gantt_7 | 2025-06-16 | 2025-09-13 | 2025-06-16 | 2025-06-18 | 2025-09-15 | 2025-06-18 | 305 | 305 |
| 000308 |  | Limpieza de terreno manual | 13d | 2025-06-18 | 2025-07-01 | 000305 | 89d | 0d | 5.2.6.4 | 646 | Cronograma Gantt_7 | 2025-06-18 | 2025-09-15 | 2025-06-18 | 2025-07-01 | 2025-09-28 | 2025-07-01 | 308 | 308 |
| 000309 |  | Excavaciones no clasificada para estructuras | 1d | 2025-07-01 | 2025-07-02 | 000308 | 89d | 0d | 5.2.6.5 | 647 | Cronograma Gantt_7 | 2025-07-01 | 2025-09-28 | 2025-07-01 | 2025-07-02 | 2025-09-29 | 2025-07-02 | 309 | 309 |
| 000310 |  | Excavacion no clasificada de zanja | 5d | 2025-07-01 | 2025-07-06 | 000308 | 122d | 0d | 5.2.6.6 | 648 | Cronograma Gantt_7 | 2025-07-01 | 2025-10-31 | 2025-07-01 | 2025-07-06 | 2025-11-05 | 2025-07-06 | 310 | 310 |
| 000311 |  | Relleno estructural | 5d | 2025-07-02 | 2025-07-07 | 000309 | 89d | 0d | 5.2.6.7 | 649 | Cronograma Gantt_7 | 2025-07-02 | 2025-09-29 | 2025-07-02 | 2025-07-07 | 2025-10-04 | 2025-07-07 | 311 | 311 |
| 000306 |  | Desvío provisional con tubería | 2d | 2025-07-06 | 2025-07-08 | 000310 | 127d | 88d | 5.2.6.2 | 644 | Cronograma Gantt_7 | 2025-07-06 | 2025-11-10 | 2025-07-06 | 2025-07-08 | 2025-11-12 | 2025-07-08 | 306 | 306 |
| 000307 |  | Desvío provisional en tierras | 7d | 2025-07-06 | 2025-07-13 | 000310 | 122d | 83d | 5.2.6.3 | 645 | Cronograma Gantt_7 | 2025-07-06 | 2025-11-05 | 2025-07-06 | 2025-07-13 | 2025-11-12 | 2025-07-13 | 307 | 307 |
| 000312 |  | Colocación de roca en uña (Alcantarillas) | 1d | 2025-07-07 | 2025-07-08 | 000311 | 127d | 88d | 5.2.6.8 | 651 | Cronograma Gantt_7 | 2025-07-07 | 2025-11-11 | 2025-07-07 | 2025-07-08 | 2025-11-12 | 2025-07-08 | 312 | 312 |
| 000313 |  | Concreto de Nivelacion (f'c=100 kg/cm2) | 1d | 2025-07-07 | 2025-07-08 | 000311 | 89d | 0d | 5.2.6.9 | 652 | Cronograma Gantt_7 | 2025-07-07 | 2025-10-04 | 2025-07-07 | 2025-07-08 | 2025-10-05 | 2025-07-08 | 313 | 313 |
| 000314 |  | Concreto Clase C (f'c=280 kg/cm2) Premezclado - Cimientos reforzados | 1d | 2025-07-08 | 2025-07-09 | 000313 | 89d | 0d | 5.2.6.10 | 654 | Cronograma Gantt_7 | 2025-07-08 | 2025-10-05 | 2025-07-08 | 2025-07-09 | 2025-10-06 | 2025-07-09 | 314 | 314 |
| 000318 |  | Acero de refuerzo f'y=4200kg/cm2 | 9d | 2025-07-09 | 2025-07-18 | 000314 | 89d | 0d | 5.2.6.14 | 658 | Cronograma Gantt_7 | 2025-07-09 | 2025-10-06 | 2025-07-09 | 2025-07-18 | 2025-10-15 | 2025-07-18 | 318 | 318 |
| 000316 |  | Encofrado y Desencofrado Caravista | 9d | 2025-07-18 | 2025-07-27 | 000318 | 89d | 0d | 5.2.6.12 | 656 | Cronograma Gantt_7 | 2025-07-18 | 2025-10-15 | 2025-07-18 | 2025-07-27 | 2025-10-24 | 2025-07-27 | 316 | 316 |
| 000317 |  | Encofrado y Desencofrado Cara Oculta | 7d | 2025-07-18 | 2025-07-25 | 000318 | 110d | 71d | 5.2.6.13 | 657 | Cronograma Gantt_7 | 2025-07-18 | 2025-11-05 | 2025-07-18 | 2025-07-25 | 2025-11-12 | 2025-07-25 | 317 | 317 |
| 000315 |  | Concreto Clase C (f'c=280 kg/cm2) Premezclado - Muros de contencion | 1d | 2025-07-27 | 2025-07-28 | 000316 | 89d | 0d | 5.2.6.11 | 655 | Cronograma Gantt_7 | 2025-07-27 | 2025-10-24 | 2025-07-27 | 2025-07-28 | 2025-10-25 | 2025-07-28 | 315 | 315 |
| 000319 |  | Emboquillado de piedra e=0.20m | 18d | 2025-07-28 | 2025-08-15 | 000315 | 89d | 50d | 5.2.6.15 | 659 | Cronograma Gantt_7 | 2025-07-28 | 2025-10-25 | 2025-07-28 | 2025-08-15 | 2025-11-12 | 2025-08-15 | 319 | 319 |
| 000320 |  | Emboquillado de piedra e=0.30m | 1d | 2025-07-28 | 2025-07-29 | 000315 | 106d | 67d | 5.2.6.16 | 660 | Cronograma Gantt_7 | 2025-07-28 | 2025-11-11 | 2025-07-28 | 2025-07-29 | 2025-11-12 | 2025-07-29 | 320 | 320 |
| 000321 |  | Emboquillado de piedra e=0.50m | 2d | 2025-07-28 | 2025-07-30 | 000315 | 105d | 66d | 5.2.6.17 | 661 | Cronograma Gantt_7 | 2025-07-28 | 2025-11-10 | 2025-07-28 | 2025-07-30 | 2025-11-12 | 2025-07-30 | 321 | 321 |
| 000322 |  | Sello en juntas | 4d | 2025-07-28 | 2025-08-01 | 000315 | 103d | 64d | 5.2.6.18 | 666 | Cronograma Gantt_7 | 2025-07-28 | 2025-11-08 | 2025-07-28 | 2025-08-01 | 2025-11-12 | 2025-08-01 | 322 | 322 |
| 000323 |  | Pintura bituminosa | 5d | 2025-07-28 | 2025-08-02 | 000315 | 102d | 63d | 5.2.6.19 | 668 | Cronograma Gantt_7 | 2025-07-28 | 2025-11-07 | 2025-07-28 | 2025-08-02 | 2025-11-12 | 2025-08-02 | 323 | 323 |
|  | 000324 | **DI-PR-47bis-D / DE-PR-49bis-D** |  | 2025-06-15 | 2025-10-25 |  |  |  |  |  |  |  |  |  |  |  |  |  |  |
|  | 000325 | **Excavaciones** |  | 2025-06-15 | 2025-08-09 |  |  |  |  |  |  |  |  |  |  |  |  |  |  |
| 000326 |  | Desbroce | 3d | 2025-06-15 | 2025-06-18 | 000020 | 0d |  | 5.3.1.1 | 692 | Cronograma Gantt_7 | 2025-06-15 | 2025-06-15 | 2025-06-15 | 2025-06-18 | 2025-06-18 | 2025-06-18 | 326 | 326 |
| 000327 |  | Remocion de Dique Existente | 3d | 2025-06-18 | 2025-06-21 | 000326 | 0d |  | 5.3.1.2 | 693 | Cronograma Gantt_7 | 2025-06-18 | 2025-06-18 | 2025-06-18 | 2025-06-21 | 2025-06-21 | 2025-06-21 | 327 | 327 |
| 000328 |  | Excavacion de Cimentacion | 15d | 2025-06-21 | 2025-07-06 | 000327 | 0d |  | 5.3.1.3 | 694 | Cronograma Gantt_7 | 2025-06-21 | 2025-06-21 | 2025-06-21 | 2025-07-06 | 2025-07-06 | 2025-07-06 | 328 | 328 |
| 000329 |  | Perfilado y Conformacion de Plataforma de Fundacion | 8d | 2025-07-01 | 2025-07-09 | 000328 FS-5d | 122d | 0d | 5.3.1.4 | 695 | Cronograma Gantt_7 | 2025-07-01 | 2025-10-31 | 2025-07-01 | 2025-07-09 | 2025-11-08 | 2025-07-09 | 329 | 329 |
| 000333 |  | Excavacion Localizada - Sobreexcavacion | 7d | 2025-07-01 | 2025-07-08 | 000328 FS-5d | 127d | 109d | 5.3.1.8 | 699 | Cronograma Gantt_7 | 2025-07-01 | 2025-11-05 | 2025-07-01 | 2025-07-08 | 2025-11-12 | 2025-07-08 | 333 | 333 |
| 000332 |  | Conformacion de Material Excedente en DMO | 4d | 2025-07-02 | 2025-07-06 | 000350 | 129d | 111d | 5.3.1.7 | 698 | Cronograma Gantt_7 | 2025-07-02 | 2025-11-08 | 2025-07-02 | 2025-07-06 | 2025-11-12 | 2025-07-06 | 332 | 332 |
| 000330 |  | Excavacion de Uña | 9d | 2025-07-04 | 2025-07-13 | 000329 FS-5d | 122d | 104d | 5.3.1.5 | 696 | Cronograma Gantt_7 | 2025-07-04 | 2025-11-03 | 2025-07-04 | 2025-07-13 | 2025-11-12 | 2025-07-13 | 330 | 330 |
| 000331 |  | Conformacion de Material Excedente en DME | 12d | 2025-07-28 | 2025-08-09 | 000352 | 95d | 77d | 5.3.1.6 | 697 | Cronograma Gantt_7 | 2025-07-28 | 2025-10-31 | 2025-07-28 | 2025-08-09 | 2025-11-12 | 2025-08-09 | 331 | 331 |

| ID | WBS | Activity | Duration | Start | Finish | Predecessors | Total float | Free float | MSP Outline Number | MSP Unique ID | MSP Project Name | Imported Early Start | Imported Late Start | Imported Start | Imported Early Finish | Imported Late Finish | Imported Finish | MSP ID | MSP Task Order |
| --- | --- | --- | --- | --- | --- | --- | --- | --- | --- | --- | --- | --- | --- | --- | --- | --- | --- | --- | --- |
|  | 000334 | **Rellenos** |  | 2025-08-17 | 2025-10-16 |  |  |  |  |  |  |  |  |  |  |  |  |  |  |
| 000335 |  | Relleno con Material Granular (incluye extraccion de material, zarandeo y combinado) | 22d | 2025-08-17 | 2025-09-08 | 000358 FS-10d | 18d | 0d | 5.3.2.1 | 702 | Cronograma Gantt_7 | 2025-08-17 | 2025-09-04 | 2025-08-17 | 2025-09-08 | 2025-09-26 | 2025-09-08 | 335 | 335 |
| 000339 |  | Relleno con Material Seleccionado (incluye extraccion de material, zarandeo y combinado) | 7d | 2025-08-27 | 2025-09-03 | 000358 | 70d | 52d | 5.3.2.5 | 706 | Cronograma Gantt_7 | 2025-08-27 | 2025-11-05 | 2025-08-27 | 2025-09-03 | 2025-11-12 | 2025-09-03 | 339 | 339 |
| 000338 |  | Perfilado de Talud Dique | 6d | 2025-09-08 | 2025-09-14 | 000335 | 18d | 0d | 5.3.2.4 | 705 | Cronograma Gantt_7 | 2025-09-08 | 2025-09-26 | 2025-09-08 | 2025-09-14 | 2025-10-02 | 2025-09-14 | 338 | 338 |
| 000337 |  | Relleno Afirmado | 2d | 2025-10-04 | 2025-10-06 | 000354, 000343 | 37d | 19d | 5.3.2.3 | 704 | Cronograma Gantt_7 | 2025-10-04 | 2025-11-10 | 2025-10-04 | 2025-10-06 | 2025-11-12 | 2025-10-06 | 337 | 337 |
| 000336 |  | Relleno sin Compactar | 5d | 2025-10-11 | 2025-10-16 | 000345 | 27d | 9d | 5.3.2.2 | 703 | Cronograma Gantt_7 | 2025-10-11 | 2025-11-07 | 2025-10-11 | 2025-10-16 | 2025-11-12 | 2025-10-16 | 336 | 336 |
| 000340 |  | Grava para Drenaje | 2d | 2025-10-11 | 2025-10-13 | 000345 | 30d | 12d | 5.3.2.6 | 707 | Cronograma Gantt_7 | 2025-10-11 | 2025-11-10 | 2025-10-11 | 2025-10-13 | 2025-11-12 | 2025-10-13 | 340 | 340 |
|  | 000341 | **Geotextil** |  | 2025-09-14 | 2025-10-04 |  |  |  |  |  |  |  |  |  |  |  |  |  |  |
| 000342 |  | Instalacion de Geotextil 400gr/m2 | 12d | 2025-09-14 | 2025-09-26 | 000338 | 18d | 0d | 5.3.3.1 | 710 | Cronograma Gantt_7 | 2025-09-14 | 2025-10-02 | 2025-09-14 | 2025-09-26 | 2025-10-14 | 2025-09-26 | 342 | 342 |
| 000343 |  | Zanja de Anclaje | 13d | 2025-09-21 | 2025-10-04 | 000360, 000342 FS-5d | 37d | 0d | 5.3.3.2 | 711 | Cronograma Gantt_7 | 2025-09-21 | 2025-10-28 | 2025-09-21 | 2025-10-04 | 2025-11-10 | 2025-10-04 | 343 | 343 |
|  | 000344 | **Colocacion de Roca** |  | 2025-06-21 | 2025-10-25 |  |  |  |  |  |  |  |  |  |  |  |  |  |  |
| 000347 |  | Extraccion de Rocas Reutilizables | 7d | 2025-06-21 | 2025-06-28 | 000327 | 137d | 119d | 5.3.4.3 | 716 | Cronograma Gantt_7 | 2025-06-21 | 2025-11-05 | 2025-06-21 | 2025-06-28 | 2025-11-12 | 2025-06-28 | 347 | 347 |
| 000345 |  | Colocacion de Roca en Uña | 15d | 2025-09-26 | 2025-10-11 | 000342 | 18d | 0d | 5.3.4.1 | 714 | Cronograma Gantt_7 | 2025-09-26 | 2025-10-14 | 2025-09-26 | 2025-10-11 | 2025-10-29 | 2025-10-11 | 345 | 345 |
| 000346 |  | Colocacion de Roca en Talud | 24d | 2025-10-01 | 2025-10-25 | 000356, 000345 SS+5d | 18d | 0d | 5.3.4.2 | 715 | Cronograma Gantt_7 | 2025-10-01 | 2025-10-19 | 2025-10-01 | 2025-10-25 | 2025-11-12 | 2025-10-25 | 346 | 346 |
|  | 000348 | **Transportes** |  | 2025-06-18 | 2025-09-23 |  |  |  |  |  |  |  |  |  |  |  |  |  |  |
| 000349 |  | Transporte de Material Organico (a DMO) D<=1km | 7d | 2025-06-18 | 2025-06-25 | 000326 | 129d | 0d | 5.3.5.1 | 725 | Cronograma Gantt_7 | 2025-06-18 | 2025-10-25 | 2025-06-18 | 2025-06-25 | 2025-11-01 | 2025-06-25 | 349 | 349 |
| 000350 |  | Transporte de Material Organico (a DMO) D>1km | 14d | 2025-06-18 | 2025-07-02 | 000349 SS | 129d | 0d | 5.3.5.2 | 726 | Cronograma Gantt_7 | 2025-06-18 | 2025-10-25 | 2025-06-18 | 2025-07-02 | 2025-11-08 | 2025-07-02 | 350 | 350 |
| 000351 |  | Transporte de Material Excedente D<=1km | 25d | 2025-06-26 | 2025-07-21 | 000328 SS+5d | 18d | 0d | 5.3.5.3 | 727 | Cronograma Gantt_7 | 2025-06-26 | 2025-07-14 | 2025-06-26 | 2025-07-21 | 2025-08-08 | 2025-07-21 | 351 | 351 |
| 000352 |  | Transporte de Material Excedente D>1km | 32d | 2025-06-26 | 2025-07-28 | 000351 SS | 18d | 0d | 5.3.5.4 | 728 | Cronograma Gantt_7 | 2025-06-26 | 2025-07-14 | 2025-06-26 | 2025-07-28 | 2025-08-15 | 2025-07-28 | 352 | 352 |
| 000357 |  | Transporte de Material de Prestamo Cantera de Rio (Cuerpo de Terraplen) D<=1km | 30d | 2025-07-23 | 2025-08-22 | 000352 FS-5d | 18d | 0d | 5.3.5.9 | 733 | Cronograma Gantt_7 | 2025-07-23 | 2025-08-10 | 2025-07-23 | 2025-08-22 | 2025-09-09 | 2025-08-22 | 357 | 357 |
| 000358 |  | Transporte de Material de Prestamo Cantera de Rio (Cuerpo de Terraplen) D>1km | 35d | 2025-07-23 | 2025-08-27 | 000357 SS | 18d | 0d | 5.3.5.10 | 734 | Cronograma Gantt_7 | 2025-07-23 | 2025-08-10 | 2025-07-23 | 2025-08-27 | 2025-09-14 | 2025-08-27 | 358 | 358 |
| 000355 |  | Transporte de Roca D<=1km | 32d | 2025-08-22 | 2025-09-23 | 000358 FS-5d | 27d | 0d | 5.3.5.7 | 731 | Cronograma Gantt_7 | 2025-08-22 | 2025-09-18 | 2025-08-22 | 2025-09-23 | 2025-10-20 | 2025-09-23 | 355 | 355 |
| 000356 |  | Transporte de Roca D>1km | 31d | 2025-08-22 | 2025-09-22 | 000355 SS | 27d | 9d | 5.3.5.8 | 732 | Cronograma Gantt_7 | 2025-08-22 | 2025-09-18 | 2025-08-22 | 2025-09-22 | 2025-10-19 | 2025-09-22 | 356 | 356 |
| 000359 |  | Transporte de Material Seleccionado para Zanja D<=1km | 1d | 2025-08-27 | 2025-08-28 | 000358 | 52d | 0d | 5.3.5.11 | 735 | Cronograma Gantt_7 | 2025-08-27 | 2025-10-18 | 2025-08-27 | 2025-08-28 | 2025-10-19 | 2025-08-28 | 359 | 359 |
| 000360 |  | Transporte de Material Seleccionado para Zanja D>1km | 1d | 2025-08-27 | 2025-08-28 | 000359 SS | 52d | 0d | 5.3.5.12 | 736 | Cronograma Gantt_7 | 2025-08-27 | 2025-10-18 | 2025-08-27 | 2025-08-28 | 2025-10-19 | 2025-08-28 | 360 | 360 |
| 000353 |  | Transporte de Material de Prestamo (Afirmado) D<=1km | 19d | 2025-08-28 | 2025-09-16 | 000360 | 52d | 0d | 5.3.5.5 | 729 | Cronograma Gantt_7 | 2025-08-28 | 2025-10-19 | 2025-08-28 | 2025-09-16 | 2025-11-07 | 2025-09-16 | 353 | 353 |
| 000354 |  | Transporte de Material de Prestamo (Afirmado) D>1km | 22d | 2025-08-28 | 2025-09-19 | 000353 SS | 52d | 15d | 5.3.5.6 | 730 | Cronograma Gantt_7 | 2025-08-28 | 2025-10-19 | 2025-08-28 | 2025-09-19 | 2025-11-10 | 2025-09-19 | 354 | 354 |

| ID | WBS | Activity | Duration | Start | Finish | Predecessors | Total float | Free float | MSP Outline Number | MSP Unique ID | MSP Project Name | Imported Early Start | Imported Late Start | Imported Start | Imported Early Finish | Imported Late Finish | Imported Finish | MSP ID | MSP Task Order |
| --- | --- | --- | --- | --- | --- | --- | --- | --- | --- | --- | --- | --- | --- | --- | --- | --- | --- | --- | --- |
|  | 000361 | **DI-PR-40A-D / DI-PR-40B-D** |  | 2024-06-13 | 2025-10-19 |  |  |  |  |  |  |  |  |  |  |  |  |  |  |
|  | 000362 | **Excavaciones** |  | 2025-07-06 | 2025-08-26 |  |  |  |  |  |  |  |  |  |  |  |  |  |  |
| 000363 |  | Desbroce | 1d | 2025-07-06 | 2025-07-07 | 000022 | 0d |  | 5.4.1.1 | 884 | Cronograma Gantt_7 | 2025-07-06 | 2025-07-06 | 2025-07-06 | 2025-07-07 | 2025-07-07 | 2025-07-07 | 363 | 363 |
| 000364 |  | Remocion de Dique Existente | 3d | 2025-07-07 | 2025-07-10 | 000363 | 0d |  | 5.4.1.2 | 885 | Cronograma Gantt_7 | 2025-07-07 | 2025-07-07 | 2025-07-07 | 2025-07-10 | 2025-07-10 | 2025-07-10 | 364 | 364 |
| 000365 |  | Excavacion de Cimentacion | 20d | 2025-07-10 | 2025-07-30 | 000364 | 0d |  | 5.4.1.3 | 886 | Cronograma Gantt_7 | 2025-07-10 | 2025-07-10 | 2025-07-10 | 2025-07-30 | 2025-07-30 | 2025-07-30 | 365 | 365 |
| 000369 |  | Conformacion de Material Excedente en DMO | 2d | 2025-07-15 | 2025-07-17 | 000390 | 118d | 94d | 5.4.1.7 | 890 | Cronograma Gantt_7 | 2025-07-15 | 2025-11-10 | 2025-07-15 | 2025-07-17 | 2025-11-12 | 2025-07-17 | 369 | 369 |
| 000366 |  | Perfilado y Conformacion de Plataforma de Fundacion | 3d | 2025-07-30 | 2025-08-02 | 000365 | 102d | 78d | 5.4.1.4 | 887 | Cronograma Gantt_7 | 2025-07-30 | 2025-11-09 | 2025-07-30 | 2025-08-02 | 2025-11-12 | 2025-08-02 | 366 | 366 |
| 000367 |  | Excavacion de Uña | 12d | 2025-07-30 | 2025-08-11 | 000365 | 34d | 0d | 5.4.1.5 | 888 | Cronograma Gantt_7 | 2025-07-30 | 2025-09-02 | 2025-07-30 | 2025-08-11 | 2025-09-14 | 2025-08-11 | 367 | 367 |
| 000368 |  | Conformacion de Material Excedente en DME | 12d | 2025-08-14 | 2025-08-26 | 000392 | 78d | 54d | 5.4.1.6 | 889 | Cronograma Gantt_7 | 2025-08-14 | 2025-10-31 | 2025-08-14 | 2025-08-26 | 2025-11-12 | 2025-08-26 | 368 | 368 |
|  | 000370 | **Rellenos** |  | 2024-06-13 | 2025-09-19 |  |  |  |  |  |  |  |  |  |  |  |  |  |  |
| 000375 |  | Grava para Drenaje | 1d | 2024-06-13 | 2024-06-14 |  | 516d | 492d | 5.4.2.5 | 899 | Cronograma Gantt_7 | 2024-06-13 | 2025-11-11 | 2024-06-13 | 2024-06-14 | 2025-11-12 | 2024-06-14 | 375 | 375 |
| 000374 |  | Relleno con Material Seleccionado (incluye extraccion de material, zarandeo y combinado) | 8d | 2025-08-17 | 2025-08-25 | 000398 FS-5d | 24d | 0d | 5.4.2.4 | 898 | Cronograma Gantt_7 | 2025-08-17 | 2025-09-10 | 2025-08-17 | 2025-08-25 | 2025-09-18 | 2025-08-25 | 374 | 374 |
| 000371 |  | Relleno con Material Granular (incluye extraccion de material, zarandeo y combinado) | 2d | 2025-08-22 | 2025-08-24 | 000398 | 80d | 56d | 5.4.2.1 | 894 | Cronograma Gantt_7 | 2025-08-22 | 2025-11-10 | 2025-08-22 | 2025-08-24 | 2025-11-12 | 2025-08-24 | 371 | 371 |
| 000373 |  | Perfilado de Talud Dique | 1d | 2025-08-25 | 2025-08-26 | 000374 | 24d | 0d | 5.4.2.3 | 897 | Cronograma Gantt_7 | 2025-08-25 | 2025-09-18 | 2025-08-25 | 2025-08-26 | 2025-09-19 | 2025-08-26 | 373 | 373 |
| 000372 |  | Relleno Afirmado | 1d | 2025-09-18 | 2025-09-19 | 000394, 000378 | 54d | 30d | 5.4.2.2 | 896 | Cronograma Gantt_7 | 2025-09-18 | 2025-11-11 | 2025-09-18 | 2025-09-19 | 2025-11-12 | 2025-09-19 | 372 | 372 |
|  | 000376 | **Geotextil** |  | 2025-08-26 | 2025-09-18 |  |  |  |  |  |  |  |  |  |  |  |  |  |  |
| 000377 |  | Instalacion de Geotextil 400gr/m2 | 20d | 2025-08-26 | 2025-09-15 | 000373 | 24d | 0d | 5.4.3.1 | 902 | Cronograma Gantt_7 | 2025-08-26 | 2025-09-19 | 2025-08-26 | 2025-09-15 | 2025-10-09 | 2025-09-15 | 377 | 377 |
| 000378 |  | Zanja de Anclaje | 13d | 2025-09-05 | 2025-09-18 | 000400, 000377 SS+10d | 54d | 0d | 5.4.3.2 | 903 | Cronograma Gantt_7 | 2025-09-05 | 2025-10-29 | 2025-09-05 | 2025-09-18 | 2025-11-11 | 2025-09-18 | 378 | 378 |
|  | 000379 | **Colocacion de Roca** |  | 2025-07-10 | 2025-10-19 |  |  |  |  |  |  |  |  |  |  |  |  |  |  |
| 000382 |  | Extraccion de Rocas Reutilizables | 7d | 2025-07-10 | 2025-07-17 | 000364 | 118d | 94d | 5.4.4.3 | 908 | Cronograma Gantt_7 | 2025-07-10 | 2025-11-05 | 2025-07-10 | 2025-07-17 | 2025-11-12 | 2025-07-17 | 382 | 382 |
| 000385 |  | Desmontaje y Recolocacion de Enrocado | 2d | 2025-08-11 | 2025-08-13 | 000367 | 34d | 0d | 5.4.4.6 | 912 | Cronograma Gantt_7 | 2025-08-11 | 2025-09-14 | 2025-08-11 | 2025-08-13 | 2025-09-16 | 2025-08-13 | 385 | 385 |
| 000387 |  | Rehabilitacion de Enrocados de Proteccion Existentes | 37d | 2025-08-13 | 2025-09-19 | 000385 | 34d | 0d | 5.4.4.8 | 915 | Cronograma Gantt_7 | 2025-08-13 | 2025-09-16 | 2025-08-13 | 2025-09-19 | 2025-10-23 | 2025-09-19 | 387 | 387 |
| 000380 |  | Colocacion de Roca en Uña | 20d | 2025-09-15 | 2025-10-05 | 000396, 000377 | 24d | 0d | 5.4.4.1 | 906 | Cronograma Gantt_7 | 2025-09-15 | 2025-10-09 | 2025-09-15 | 2025-10-05 | 2025-10-29 | 2025-10-05 | 380 | 380 |
| 000384 |  | Malla Gavion de 1m x 1m x 5m | 19d | 2025-09-19 | 2025-10-08 | 000387 | 34d | 0d | 5.4.4.5 | 910 | Cronograma Gantt_7 | 2025-09-19 | 2025-10-23 | 2025-09-19 | 2025-10-08 | 2025-11-11 | 2025-10-08 | 384 | 384 |
| 000381 |  | Colocacion de Roca en Talud | 19d | 2025-09-20 | 2025-10-09 | 000380 SS+5d | 24d | 0d | 5.4.4.2 | 907 | Cronograma Gantt_7 | 2025-09-20 | 2025-10-14 | 2025-09-20 | 2025-10-09 | 2025-11-02 | 2025-10-09 | 381 | 381 |
| 000383 |  | Proteccion de Talud con Colchon Reno 6m Largo x e=0.30cm | 1d | 2025-10-08 | 2025-10-09 | 000384 | 34d | 10d | 5.4.4.4 | 909 | Cronograma Gantt_7 | 2025-10-08 | 2025-11-11 | 2025-10-08 | 2025-10-09 | 2025-11-12 | 2025-10-09 | 383 | 383 |
| 000386 |  | Colocación de Roca en Corona | 10d | 2025-10-09 | 2025-10-19 | 000381 | 24d | 0d | 5.4.4.7 | 913 | Cronograma Gantt_7 | 2025-10-09 | 2025-11-02 | 2025-10-09 | 2025-10-19 | 2025-11-12 | 2025-10-19 | 386 | 386 |

| ID | WBS | Activity | Duration | Start | Finish | Predecessors | Total float | Free float | MSP Outline Number | MSP Unique ID | MSP Project Name | Imported Early Start | Imported Late Start | Imported Start | Imported Early Finish | Imported Late Finish | Imported Finish | MSP ID | MSP Task Order |
| --- | --- | --- | --- | --- | --- | --- | --- | --- | --- | --- | --- | --- | --- | --- | --- | --- | --- | --- | --- |
|  | 000388 | **Transportes** |  | 2025-07-07 | 2025-09-01 |  |  |  |  |  |  |  |  |  |  |  |  |  |  |
| 000389 |  | Transporte de Material Organico (a DMO) D<=1km | 5d | 2025-07-07 | 2025-07-12 | 000363 | 118d | 0d | 5.4.5.1 | 917 | Cronograma Gantt_7 | 2025-07-07 | 2025-11-02 | 2025-07-07 | 2025-07-12 | 2025-11-07 | 2025-07-12 | 389 | 389 |
| 000390 |  | Transporte de Material Organico (a DMO) D>1km | 8d | 2025-07-07 | 2025-07-15 | 000389 SS | 118d | 0d | 5.4.5.2 | 918 | Cronograma Gantt_7 | 2025-07-07 | 2025-11-02 | 2025-07-07 | 2025-07-15 | 2025-11-10 | 2025-07-15 | 390 | 390 |
| 000391 |  | Transporte de Material Excedente D<=1km | 22d | 2025-07-20 | 2025-08-11 | 000365 FS-10d | 24d | 0d | 5.4.5.3 | 919 | Cronograma Gantt_7 | 2025-07-20 | 2025-08-13 | 2025-07-20 | 2025-08-11 | 2025-09-04 | 2025-08-11 | 391 | 391 |
| 000392 |  | Transporte de Material Excedente D>1km | 15d | 2025-07-30 | 2025-08-14 | 000391 FS-12d | 78d | 0d | 5.4.5.4 | 920 | Cronograma Gantt_7 | 2025-07-30 | 2025-10-16 | 2025-07-30 | 2025-08-14 | 2025-10-31 | 2025-08-14 | 392 | 392 |
| 000397 |  | Transporte de Material de Prestamo Cantera de Rio (Cuerpo de Terraplen) D<=1km | 9d | 2025-08-06 | 2025-08-15 | 000391 FS-5d | 24d | 0d | 5.4.5.9 | 925 | Cronograma Gantt_7 | 2025-08-06 | 2025-08-30 | 2025-08-06 | 2025-08-15 | 2025-09-08 | 2025-08-15 | 397 | 397 |
| 000398 |  | Transporte de Material de Prestamo Cantera de Rio (Cuerpo de Terraplen) D>1km | 16d | 2025-08-06 | 2025-08-22 | 000397 SS | 24d | 0d | 5.4.5.10 | 926 | Cronograma Gantt_7 | 2025-08-06 | 2025-08-30 | 2025-08-06 | 2025-08-22 | 2025-09-15 | 2025-08-22 | 398 | 398 |
| 000395 |  | Transporte de Roca D<=1km | 8d | 2025-08-20 | 2025-08-28 | 000398 FS-2d | 38d | 0d | 5.4.5.7 | 923 | Cronograma Gantt_7 | 2025-08-20 | 2025-09-27 | 2025-08-20 | 2025-08-28 | 2025-10-05 | 2025-08-28 | 395 | 395 |
| 000396 |  | Transporte de Roca D>1km | 12d | 2025-08-20 | 2025-09-01 | 000395 SS | 38d | 14d | 5.4.5.8 | 924 | Cronograma Gantt_7 | 2025-08-20 | 2025-09-27 | 2025-08-20 | 2025-09-01 | 2025-10-09 | 2025-09-01 | 396 | 396 |
| 000399 |  | Transporte de Material Seleccionado para Zanja D<=1km | 1d | 2025-08-22 | 2025-08-23 | 000398 | 67d | 0d | 5.4.5.11 | 927 | Cronograma Gantt_7 | 2025-08-22 | 2025-10-28 | 2025-08-22 | 2025-08-23 | 2025-10-29 | 2025-08-23 | 399 | 399 |
| 000400 |  | Transporte de Material Seleccionado para Zanja D>1km | 1d | 2025-08-22 | 2025-08-23 | 000399 SS | 67d | 0d | 5.4.5.12 | 928 | Cronograma Gantt_7 | 2025-08-22 | 2025-10-28 | 2025-08-22 | 2025-08-23 | 2025-10-29 | 2025-08-23 | 400 | 400 |
| 000393 |  | Transporte de Material de Prestamo (Afirmado) D<=1km | 8d | 2025-08-23 | 2025-08-31 | 000400 | 72d | 0d | 5.4.5.5 | 921 | Cronograma Gantt_7 | 2025-08-23 | 2025-11-03 | 2025-08-23 | 2025-08-31 | 2025-11-11 | 2025-08-31 | 393 | 393 |
| 000394 |  | Transporte de Material de Prestamo (Afirmado) D>1km | 8d | 2025-08-23 | 2025-08-31 | 000393 SS | 72d | 18d | 5.4.5.6 | 922 | Cronograma Gantt_7 | 2025-08-23 | 2025-11-03 | 2025-08-23 | 2025-08-31 | 2025-11-11 | 2025-08-31 | 394 | 394 |
|  | 000401 | **Otros** |  | 2025-07-30 | 2025-08-06 |  |  |  |  |  |  |  |  |  |  |  |  |  |  |
|  | 000402 | **Via Carrozable** |  | 2025-07-30 | 2025-08-06 |  |  |  |  |  |  |  |  |  |  |  |  |  |  |
| 000403 |  | Material de Base para pavimento | 1d | 2025-07-30 | 2025-07-31 | 000365 | 98d | 0d | 5.4.6.1.1 | 1283 | Cronograma Gantt_7 | 2025-07-30 | 2025-11-05 | 2025-07-30 | 2025-07-31 | 2025-11-06 | 2025-07-31 | 403 | 403 |
| 000404 |  | Pavimento Emboquillado e=0.25m | 6d | 2025-07-31 | 2025-08-06 | 000403 | 98d | 74d | 5.4.6.1.2 | 1286 | Cronograma Gantt_7 | 2025-07-31 | 2025-11-06 | 2025-07-31 | 2025-08-06 | 2025-11-12 | 2025-08-06 | 404 | 404 |
|  | 000405 | **DI-PR-42-1-I / DI-PR-42-3-I** |  | 2025-07-30 | 2025-11-12 |  |  |  |  |  |  |  |  |  |  |  |  |  |  |
|  | 000406 | **Excavaciones** |  | 2025-07-30 | 2025-09-29 |  |  |  |  |  |  |  |  |  |  |  |  |  |  |
| 000407 |  | Desbroce | 2d | 2025-07-30 | 2025-08-01 | 000024 | 0d |  | 5.5.1.1 | 979 | Cronograma Gantt_7 | 2025-07-30 | 2025-07-30 | 2025-07-30 | 2025-08-01 | 2025-08-01 | 2025-08-01 | 407 | 407 |
| 000408 |  | Remocion de Dique Existente | 10d | 2025-08-01 | 2025-08-11 | 000407 | 12d | 0d | 5.5.1.2 | 980 | Cronograma Gantt_7 | 2025-08-01 | 2025-08-13 | 2025-08-01 | 2025-08-11 | 2025-08-23 | 2025-08-11 | 408 | 408 |
| 000409 |  | Excavacion de Cimentacion | 18d | 2025-08-11 | 2025-08-29 | 000408 | 12d | 0d | 5.5.1.3 | 981 | Cronograma Gantt_7 | 2025-08-11 | 2025-08-23 | 2025-08-11 | 2025-08-29 | 2025-09-10 | 2025-08-29 | 409 | 409 |
| 000411 |  | Excavacion de Uña | 10d | 2025-08-16 | 2025-08-26 | 000409 SS+5d | 78d |  | 5.5.1.5 | 983 | Cronograma Gantt_7 | 2025-08-16 | 2025-11-02 | 2025-08-16 | 2025-08-26 | 2025-11-12 | 2025-08-26 | 411 | 411 |
| 000413 |  | Conformacion de Material Excedente en DMO | 3d | 2025-08-21 | 2025-08-24 | 000430 | 80d |  | 5.5.1.7 | 985 | Cronograma Gantt_7 | 2025-08-21 | 2025-11-09 | 2025-08-21 | 2025-08-24 | 2025-11-12 | 2025-08-24 | 413 | 413 |
| 000410 |  | Perfilado y Conformacion de Plataforma de Fundacion | 5d | 2025-08-29 | 2025-09-03 | 000409 | 12d | 2d | 5.5.1.4 | 982 | Cronograma Gantt_7 | 2025-08-29 | 2025-09-10 | 2025-08-29 | 2025-09-03 | 2025-09-15 | 2025-09-03 | 410 | 410 |
| 000412 |  | Conformacion de Material Excedente en DME | 10d | 2025-09-19 | 2025-09-29 | 000432 | 44d |  | 5.5.1.6 | 984 | Cronograma Gantt_7 | 2025-09-19 | 2025-11-02 | 2025-09-19 | 2025-09-29 | 2025-11-12 | 2025-09-29 | 412 | 412 |

| ID | WBS | Activity | Duration | Start | Finish | Predecessors | Total float | Free float | MSP Outline Number | MSP Unique ID | MSP Project Name | Imported Early Start | Imported Late Start | Imported Start | Imported Early Finish | Imported Late Finish | Imported Finish | MSP ID | MSP Task Order |
| --- | --- | --- | --- | --- | --- | --- | --- | --- | --- | --- | --- | --- | --- | --- | --- | --- | --- | --- | --- |
|  | 000414 | **Rellenos** |  | 2025-09-05 | 2025-09-25 |  |  |  |  |  |  |  |  |  |  |  |  |  |  |
| 000415 |  | Relleno con Material Granular (incluye extraccion de material, zarandeo y combinado) | 2d | 2025-09-05 | 2025-09-07 | 000438, 000410 | 10d |  | 5.5.2.1 | 989 | Cronograma Gantt_7 | 2025-09-05 | 2025-09-15 | 2025-09-05 | 2025-09-07 | 2025-09-17 | 2025-09-07 | 415 | 415 |
| 000417 |  | Relleno con Material Seleccionado (incluye extraccion de material, zarandeo y combinado) | 7d | 2025-09-17 | 2025-09-24 | 000434, 000415 | 0d |  | 5.5.2.3 | 993 | Cronograma Gantt_7 | 2025-09-17 | 2025-09-17 | 2025-09-17 | 2025-09-24 | 2025-09-24 | 2025-09-24 | 417 | 417 |
| 000416 |  | Perfilado de Talud Dique | 1d | 2025-09-24 | 2025-09-25 | 000417 | 0d |  | 5.5.2.2 | 992 | Cronograma Gantt_7 | 2025-09-24 | 2025-09-24 | 2025-09-24 | 2025-09-25 | 2025-09-25 | 2025-09-25 | 416 | 416 |
|  | 000418 | **Geotextil** |  | 2025-09-25 | 2025-10-24 |  |  |  |  |  |  |  |  |  |  |  |  |  |  |
| 000419 |  | Instalacion de Geotextil 400gr/m2 | 21d | 2025-09-25 | 2025-10-16 | 000416 | 0d |  | 5.5.3.1 | 997 | Cronograma Gantt_7 | 2025-09-25 | 2025-09-25 | 2025-09-25 | 2025-10-16 | 2025-10-16 | 2025-10-16 | 419 | 419 |
| 000420 |  | Zanja de Anclaje | 13d | 2025-10-11 | 2025-10-24 | 000440, 000419 FS-5d | 19d |  | 5.5.3.2 | 998 | Cronograma Gantt_7 | 2025-10-11 | 2025-10-30 | 2025-10-11 | 2025-10-24 | 2025-11-12 | 2025-10-24 | 420 | 420 |
|  | 000421 | **Colocacion de Roca** |  | 2025-08-11 | 2025-11-12 |  |  |  |  |  |  |  |  |  |  |  |  |  |  |
| 000424 |  | Extraccion de Rocas Reutilizables | 9d | 2025-08-11 | 2025-08-20 | 000408 | 84d |  | 5.5.4.3 | 1003 | Cronograma Gantt_7 | 2025-08-11 | 2025-11-03 | 2025-08-11 | 2025-08-20 | 2025-11-12 | 2025-08-20 | 424 | 424 |
| 000427 |  | Rehabilitacion de Enrocados de Proteccion Existentes | 30d | 2025-08-11 | 2025-09-10 | 000408 | 63d |  | 5.5.4.6 | 1010 | Cronograma Gantt_7 | 2025-08-11 | 2025-10-13 | 2025-08-11 | 2025-09-10 | 2025-11-12 | 2025-09-10 | 427 | 427 |
| 000425 |  | Proteccion de Talud con Colchon Reno 6m Largo x e=0.30cm | 3d | 2025-09-25 | 2025-09-28 | 000416 | 45d |  | 5.5.4.4 | 1004 | Cronograma Gantt_7 | 2025-09-25 | 2025-11-09 | 2025-09-25 | 2025-09-28 | 2025-11-12 | 2025-09-28 | 425 | 425 |
| 000422 |  | Colocacion de Roca en Uña | 10d | 2025-10-16 | 2025-10-26 | 000436, 000419 | 0d |  | 5.5.4.1 | 1001 | Cronograma Gantt_7 | 2025-10-16 | 2025-10-16 | 2025-10-16 | 2025-10-26 | 2025-10-26 | 2025-10-26 | 422 | 422 |
| 000423 |  | Colocacion de Roca en Talud | 18d | 2025-10-18 | 2025-11-05 | 000422 SS+2d | 0d |  | 5.5.4.2 | 1002 | Cronograma Gantt_7 | 2025-10-18 | 2025-10-18 | 2025-10-18 | 2025-11-05 | 2025-11-05 | 2025-11-05 | 423 | 423 |
| 000426 |  | Colocación de Roca en Corona | 7d | 2025-11-05 | 2025-11-12 | 000423 | 0d |  | 5.5.4.5 | 1008 | Cronograma Gantt_7 | 2025-11-05 | 2025-11-05 | 2025-11-05 | 2025-11-12 | 2025-11-12 | 2025-11-12 | 426 | 426 |
|  | 000428 | **Transportes** |  | 2025-08-01 | 2025-10-07 |  |  |  |  |  |  |  |  |  |  |  |  |  |  |
| 000429 |  | Transporte de Material Organico (a DMO) D<=1km | 6d | 2025-08-01 | 2025-08-07 | 000407 | 0d |  | 5.5.5.1 | 1012 | Cronograma Gantt_7 | 2025-08-01 | 2025-08-01 | 2025-08-01 | 2025-08-07 | 2025-08-07 | 2025-08-07 | 429 | 429 |
| 000430 |  | Transporte de Material Organico (a DMO) D>1km | 20d | 2025-08-01 | 2025-08-21 | 000429 SS | 0d |  | 5.5.5.2 | 1013 | Cronograma Gantt_7 | 2025-08-01 | 2025-08-01 | 2025-08-01 | 2025-08-21 | 2025-08-21 | 2025-08-21 | 430 | 430 |
| 000437 |  | Transporte de Material de Prestamo Cantera de Rio (Cuerpo de Terraplen) D<=1km | 9d | 2025-08-21 | 2025-08-30 | 000430 | 0d |  | 5.5.5.9 | 1020 | Cronograma Gantt_7 | 2025-08-21 | 2025-08-21 | 2025-08-21 | 2025-08-30 | 2025-08-30 | 2025-08-30 | 437 | 437 |
| 000438 |  | Transporte de Material de Prestamo Cantera de Rio (Cuerpo de Terraplen) D>1km | 15d | 2025-08-21 | 2025-09-05 | 000437 SS | 0d |  | 5.5.5.10 | 1021 | Cronograma Gantt_7 | 2025-08-21 | 2025-08-21 | 2025-08-21 | 2025-09-05 | 2025-09-05 | 2025-09-05 | 438 | 438 |
| 000431 |  | Transporte de Material Excedente D<=1km | 18d | 2025-08-24 | 2025-09-11 | 000409 FS-5d | 44d | 0d | 5.5.5.3 | 1014 | Cronograma Gantt_7 | 2025-08-24 | 2025-10-07 | 2025-08-24 | 2025-09-11 | 2025-10-25 | 2025-09-11 | 431 | 431 |
| 000432 |  | Transporte de Material Excedente D>1km | 26d | 2025-08-24 | 2025-09-19 | 000431 SS | 44d | 0d | 5.5.5.4 | 1015 | Cronograma Gantt_7 | 2025-08-24 | 2025-10-07 | 2025-08-24 | 2025-09-19 | 2025-11-02 | 2025-09-19 | 432 | 432 |
| 000433 |  | Transporte de Material de Prestamo (Afirmado) D<=1km | 12d | 2025-09-05 | 2025-09-17 | 000438 | 0d |  | 5.5.5.5 | 1016 | Cronograma Gantt_7 | 2025-09-05 | 2025-09-05 | 2025-09-05 | 2025-09-17 | 2025-09-17 | 2025-09-17 | 433 | 433 |
| 000434 |  | Transporte de Material de Prestamo (Afirmado) D>1km | 12d | 2025-09-05 | 2025-09-17 | 000433 SS | 0d |  | 5.5.5.6 | 1017 | Cronograma Gantt_7 | 2025-09-05 | 2025-09-05 | 2025-09-05 | 2025-09-17 | 2025-09-17 | 2025-09-17 | 434 | 434 |
| 000435 |  | Transporte de Roca D<=1km | 32d | 2025-09-05 | 2025-10-07 | 000438 | 22d | 0d | 5.5.5.7 | 1018 | Cronograma Gantt_7 | 2025-09-05 | 2025-09-27 | 2025-09-05 | 2025-10-07 | 2025-10-29 | 2025-10-07 | 435 | 435 |
| 000436 |  | Transporte de Roca D>1km | 19d | 2025-09-05 | 2025-09-24 | 000435 SS | 22d |  | 5.5.5.8 | 1019 | Cronograma Gantt_7 | 2025-09-05 | 2025-09-27 | 2025-09-05 | 2025-09-24 | 2025-10-16 | 2025-09-24 | 436 | 436 |
| 000439 |  | Transporte de Material Seleccionado para Zanja D<=1km | 1d | 2025-09-05 | 2025-09-06 | 000438 | 54d | 0d | 5.5.5.11 | 1022 | Cronograma Gantt_7 | 2025-09-05 | 2025-10-29 | 2025-09-05 | 2025-09-06 | 2025-10-30 | 2025-09-06 | 439 | 439 |
| 000440 |  | Transporte de Material Seleccionado para Zanja D>1km | 1d | 2025-09-05 | 2025-09-06 | 000439 SS | 54d | 35d | 5.5.5.12 | 1023 | Cronograma Gantt_7 | 2025-09-05 | 2025-10-29 | 2025-09-05 | 2025-09-06 | 2025-10-30 | 2025-09-06 | 440 | 440 |

| ID | WBS | Activity | Duration | Start | Finish | Predecessors | Total float | Free float | MSP Outline Number | MSP Unique ID | MSP Project Name | Imported Early Start | Imported Late Start | Imported Start | Imported Early Finish | Imported Late Finish | Imported Finish | MSP ID | MSP Task Order |
| --- | --- | --- | --- | --- | --- | --- | --- | --- | --- | --- | --- | --- | --- | --- | --- | --- | --- | --- | --- |
|  | 000441 | **Otros** |  | 2025-08-01 | 2025-08-17 |  |  |  |  |  |  |  |  |  |  |  |  |  |  |
|  | 000442 | **Via Carrozable** |  | 2025-08-01 | 2025-08-17 |  |  |  |  |  |  |  |  |  |  |  |  |  |  |
| 000443 |  | Material de Base para pavimento | 1d | 2025-08-01 | 2025-08-02 | 000407 | 87d | 0d | 5.5.6.1.1 | 1070 | Cronograma Gantt_7 | 2025-08-01 | 2025-10-27 | 2025-08-01 | 2025-08-02 | 2025-10-28 | 2025-08-02 | 443 | 443 |
| 000444 |  | Pavimento Emboquillado e=0.25m | 15d | 2025-08-02 | 2025-08-17 | 000443 | 87d |  | 5.5.6.1.2 | 1071 | Cronograma Gantt_7 | 2025-08-02 | 2025-10-28 | 2025-08-02 | 2025-08-17 | 2025-11-12 | 2025-08-17 | 444 | 444 |
|  | 000445 | **DE-PR-39-I** |  | 2025-08-01 | 2025-11-08 |  |  |  |  |  |  |  |  |  |  |  |  |  |  |
|  | 000446 | **Excavaciones** |  | 2025-08-01 | 2025-09-05 |  |  |  |  |  |  |  |  |  |  |  |  |  |  |
| 000447 |  | Desbroce | 1d | 2025-08-01 | 2025-08-02 | 000026 | 0d |  | 5.6.1.1 | 1169 | Cronograma Gantt_7 | 2025-08-01 | 2025-08-01 | 2025-08-01 | 2025-08-02 | 2025-08-02 | 2025-08-02 | 447 | 447 |
| 000448 |  | Remocion de Dique Existente | 3d | 2025-08-02 | 2025-08-05 | 000447 | 0d |  | 5.6.1.2 | 1170 | Cronograma Gantt_7 | 2025-08-02 | 2025-08-02 | 2025-08-02 | 2025-08-05 | 2025-08-05 | 2025-08-05 | 448 | 448 |
| 000449 |  | Excavacion de Cimentacion | 14d | 2025-08-05 | 2025-08-19 | 000448 | 0d |  | 5.6.1.3 | 1171 | Cronograma Gantt_7 | 2025-08-05 | 2025-08-05 | 2025-08-05 | 2025-08-19 | 2025-08-19 | 2025-08-19 | 449 | 449 |
| 000454 |  | Excavacion Localizada - Sobreexcavacion | 4d | 2025-08-10 | 2025-08-14 | 000449 SS+5d | 90d | 86d | 5.6.1.8 | 1176 | Cronograma Gantt_7 | 2025-08-10 | 2025-11-08 | 2025-08-10 | 2025-08-14 | 2025-11-12 | 2025-08-14 | 454 | 454 |
| 000453 |  | Conformacion de Material Excedente en DMO | 1d | 2025-08-15 | 2025-08-16 | 000472 | 88d | 84d | 5.6.1.7 | 1175 | Cronograma Gantt_7 | 2025-08-15 | 2025-11-11 | 2025-08-15 | 2025-08-16 | 2025-11-12 | 2025-08-16 | 453 | 453 |
| 000450 |  | Perfilado y Conformacion de Plataforma de Fundacion | 2d | 2025-08-19 | 2025-08-21 | 000449 | 27d | 0d | 5.6.1.4 | 1172 | Cronograma Gantt_7 | 2025-08-19 | 2025-09-15 | 2025-08-19 | 2025-08-21 | 2025-09-17 | 2025-08-21 | 450 | 450 |
| 000451 |  | Excavacion de Uña | 6d | 2025-08-19 | 2025-08-25 | 000449 | 79d | 75d | 5.6.1.5 | 1173 | Cronograma Gantt_7 | 2025-08-19 | 2025-11-06 | 2025-08-19 | 2025-08-25 | 2025-11-12 | 2025-08-25 | 451 | 451 |
| 000452 |  | Conformacion de Material Excedente en DME | 8d | 2025-08-28 | 2025-09-05 | 000474 | 68d | 64d | 5.6.1.6 | 1174 | Cronograma Gantt_7 | 2025-08-28 | 2025-11-04 | 2025-08-28 | 2025-09-05 | 2025-11-12 | 2025-09-05 | 452 | 452 |
|  | 000455 | **Rellenos** |  | 2025-08-21 | 2025-10-25 |  |  |  |  |  |  |  |  |  |  |  |  |  |  |
| 000460 |  | Relleno con Material Seleccionado (incluye extraccion de material, zarandeo y combinado) | 4d | 2025-08-21 | 2025-08-25 | 000450 | 79d | 75d | 5.6.2.5 | 1183 | Cronograma Gantt_7 | 2025-08-21 | 2025-11-08 | 2025-08-21 | 2025-08-25 | 2025-11-12 | 2025-08-25 | 460 | 460 |
| 000456 |  | Relleno con Material Granular (incluye extraccion de material, zarandeo y combinado) | 3d | 2025-09-09 | 2025-09-12 | 000480, 000450 | 8d | 0d | 5.6.2.1 | 1179 | Cronograma Gantt_7 | 2025-09-09 | 2025-09-17 | 2025-09-09 | 2025-09-12 | 2025-09-20 | 2025-09-12 | 456 | 456 |
| 000459 |  | Perfilado de Talud Dique | 1d | 2025-09-12 | 2025-09-13 | 000456 | 8d | 0d | 5.6.2.4 | 1182 | Cronograma Gantt_7 | 2025-09-12 | 2025-09-20 | 2025-09-12 | 2025-09-13 | 2025-09-21 | 2025-09-13 | 459 | 459 |
| 000458 |  | Relleno Afirmado | 1d | 2025-10-08 | 2025-10-09 | 000476, 000464 | 8d | 4d | 5.6.2.3 | 1181 | Cronograma Gantt_7 | 2025-10-08 | 2025-10-16 | 2025-10-08 | 2025-10-09 | 2025-10-17 | 2025-10-09 | 458 | 458 |
| 000457 |  | Relleno sin Compactar | 2d | 2025-10-23 | 2025-10-25 | 000466 | 18d | 14d | 5.6.2.2 | 1180 | Cronograma Gantt_7 | 2025-10-23 | 2025-11-10 | 2025-10-23 | 2025-10-25 | 2025-11-12 | 2025-10-25 | 457 | 457 |
| 000461 |  | Grava para Drenaje | 1d | 2025-10-23 | 2025-10-24 | 000466 | 19d | 15d | 5.6.2.6 | 1184 | Cronograma Gantt_7 | 2025-10-23 | 2025-11-11 | 2025-10-23 | 2025-10-24 | 2025-11-12 | 2025-10-24 | 461 | 461 |
|  | 000462 | **Geotextil** |  | 2025-09-13 | 2025-10-08 |  |  |  |  |  |  |  |  |  |  |  |  |  |  |
| 000463 |  | Instalacion de Geotextil 400gr/m2 | 13d | 2025-09-13 | 2025-09-26 | 000459 | 8d | 0d | 5.6.3.1 | 1187 | Cronograma Gantt_7 | 2025-09-13 | 2025-09-21 | 2025-09-13 | 2025-09-26 | 2025-10-04 | 2025-09-26 | 463 | 463 |
| 000464 |  | Zanja de Anclaje | 12d | 2025-09-26 | 2025-10-08 | 000482, 000463 | 8d | 0d | 5.6.3.2 | 1188 | Cronograma Gantt_7 | 2025-09-26 | 2025-10-04 | 2025-09-26 | 2025-10-08 | 2025-10-16 | 2025-10-08 | 464 | 464 |

| ID | WBS | Activity | Duration | Start | Finish | Predecessors | Total float | Free float | MSP Outline Number | MSP Unique ID | MSP Project Name | Imported Early Start | Imported Late Start | Imported Start | Imported Early Finish | Imported Late Finish | Imported Finish | MSP ID | MSP Task Order |
| --- | --- | --- | --- | --- | --- | --- | --- | --- | --- | --- | --- | --- | --- | --- | --- | --- | --- | --- | --- |
|  | 000465 | **Colocacion de Roca** |  | 2025-08-05 | 2025-11-08 |  |  |  |  |  |  |  |  |  |  |  |  |  |  |
| 000468 |  | Extraccion de Rocas Reutilizables | 10d | 2025-08-05 | 2025-08-15 | 000448 | 89d | 85d | 5.6.4.3 | 1193 | Cronograma Gantt_7 | 2025-08-05 | 2025-11-02 | 2025-08-05 | 2025-08-15 | 2025-11-12 | 2025-08-15 | 468 | 468 |
| 000466 |  | Colocacion de Roca en Uña | 10d | 2025-10-13 | 2025-10-23 | 000478, 000458 | 4d | 0d | 5.6.4.1 | 1191 | Cronograma Gantt_7 | 2025-10-13 | 2025-10-17 | 2025-10-13 | 2025-10-23 | 2025-10-27 | 2025-10-23 | 466 | 466 |
| 000467 |  | Colocacion de Roca en Talud | 20d | 2025-10-18 | 2025-11-07 | 000466 FS-5d | 4d | 0d | 5.6.4.2 | 1192 | Cronograma Gantt_7 | 2025-10-18 | 2025-10-22 | 2025-10-18 | 2025-11-07 | 2025-11-11 | 2025-11-07 | 467 | 467 |
| 000469 |  | Enrocado Talud Encachado con Concreto | 1d | 2025-11-07 | 2025-11-08 | 000467 | 4d | 0d | 5.6.4.4 | 1196 | Cronograma Gantt_7 | 2025-11-07 | 2025-11-11 | 2025-11-07 | 2025-11-08 | 2025-11-12 | 2025-11-08 | 469 | 469 |
|  | 000470 | **Transportes** |  | 2025-08-02 | 2025-10-13 |  |  |  |  |  |  |  |  |  |  |  |  |  |  |
| 000471 |  | Transporte de Material Organico (a DMO) D<=1km | 4d | 2025-08-02 | 2025-08-06 | 000447 | 88d | 0d | 5.6.5.1 | 1202 | Cronograma Gantt_7 | 2025-08-02 | 2025-10-29 | 2025-08-02 | 2025-08-06 | 2025-11-02 | 2025-08-06 | 471 | 471 |
| 000472 |  | Transporte de Material Organico (a DMO) D>1km | 13d | 2025-08-02 | 2025-08-15 | 000471 SS | 88d | 0d | 5.6.5.2 | 1203 | Cronograma Gantt_7 | 2025-08-02 | 2025-10-29 | 2025-08-02 | 2025-08-15 | 2025-11-11 | 2025-08-15 | 472 | 472 |
| 000473 |  | Transporte de Material Excedente D<=1km | 10d | 2025-08-17 | 2025-08-27 | 000449 FS-2d | 0d |  | 5.6.5.3 | 1204 | Cronograma Gantt_7 | 2025-08-17 | 2025-08-17 | 2025-08-17 | 2025-08-27 | 2025-08-27 | 2025-08-27 | 473 | 473 |
| 000474 |  | Transporte de Material Excedente D>1km | 11d | 2025-08-17 | 2025-08-28 | 000473 SS | 0d |  | 5.6.5.4 | 1205 | Cronograma Gantt_7 | 2025-08-17 | 2025-08-17 | 2025-08-17 | 2025-08-28 | 2025-08-28 | 2025-08-28 | 474 | 474 |
| 000479 |  | Transporte de Material de Prestamo Cantera de Rio (Cuerpo de Terraplen) D<=1km | 6d | 2025-08-28 | 2025-09-03 | 000474 | 0d |  | 5.6.5.9 | 1210 | Cronograma Gantt_7 | 2025-08-28 | 2025-08-28 | 2025-08-28 | 2025-09-03 | 2025-09-03 | 2025-09-03 | 479 | 479 |
| 000480 |  | Transporte de Material de Prestamo Cantera de Rio (Cuerpo de Terraplen) D>1km | 12d | 2025-08-28 | 2025-09-09 | 000479 SS | 0d |  | 5.6.5.10 | 1211 | Cronograma Gantt_7 | 2025-08-28 | 2025-08-28 | 2025-08-28 | 2025-09-09 | 2025-09-09 | 2025-09-09 | 480 | 480 |
| 000481 |  | Transporte de Material Seleccionado para Zanja D<=1km | 1d | 2025-09-09 | 2025-09-10 | 000480 | 0d |  | 5.6.5.11 | 1212 | Cronograma Gantt_7 | 2025-09-09 | 2025-09-09 | 2025-09-09 | 2025-09-10 | 2025-09-10 | 2025-09-10 | 481 | 481 |
| 000482 |  | Transporte de Material Seleccionado para Zanja D>1km | 1d | 2025-09-09 | 2025-09-10 | 000481 SS | 0d |  | 5.6.5.12 | 1213 | Cronograma Gantt_7 | 2025-09-09 | 2025-09-09 | 2025-09-09 | 2025-09-10 | 2025-09-10 | 2025-09-10 | 482 | 482 |
| 000475 |  | Transporte de Material de Prestamo (Afirmado) D<=1km | 7d | 2025-09-10 | 2025-09-17 | 000482 | 0d |  | 5.6.5.5 | 1206 | Cronograma Gantt_7 | 2025-09-10 | 2025-09-10 | 2025-09-10 | 2025-09-17 | 2025-09-17 | 2025-09-17 | 475 | 475 |
| 000476 |  | Transporte de Material de Prestamo (Afirmado) D>1km | 9d | 2025-09-10 | 2025-09-19 | 000475 SS | 0d |  | 5.6.5.6 | 1207 | Cronograma Gantt_7 | 2025-09-10 | 2025-09-10 | 2025-09-10 | 2025-09-19 | 2025-09-19 | 2025-09-19 | 476 | 476 |
| 000477 |  | Transporte de Roca D<=1km | 20d | 2025-09-19 | 2025-10-09 | 000476 | 0d |  | 5.6.5.7 | 1208 | Cronograma Gantt_7 | 2025-09-19 | 2025-09-19 | 2025-09-19 | 2025-10-09 | 2025-10-09 | 2025-10-09 | 477 | 477 |
| 000478 |  | Transporte de Roca D>1km | 9d | 2025-10-04 | 2025-10-13 | 000477 FS-5d | 0d |  | 5.6.5.8 | 1209 | Cronograma Gantt_7 | 2025-10-04 | 2025-10-04 | 2025-10-04 | 2025-10-13 | 2025-10-13 | 2025-10-13 | 478 | 478 |
|  | 000483 | **Obras Civiles (Interferencias)** |  | 2025-08-05 | 2025-09-16 |  |  |  |  |  |  |  |  |  |  |  |  |  |  |
| 000484 |  | Trazo y replanteo de interferencia | 1d | 2025-08-05 | 2025-08-06 | 000448 | 57d | 0d | 5.6.6.1 | 1215 | Cronograma Gantt_7 | 2025-08-05 | 2025-10-01 | 2025-08-05 | 2025-08-06 | 2025-10-02 | 2025-08-06 | 484 | 484 |
| 000487 |  | Limpieza de terreno manual | 4d | 2025-08-06 | 2025-08-10 | 000484 | 57d | 0d | 5.6.6.4 | 1218 | Cronograma Gantt_7 | 2025-08-06 | 2025-10-02 | 2025-08-06 | 2025-08-10 | 2025-10-06 | 2025-08-10 | 487 | 487 |
| 000488 |  | Excavaciones no clasificada para estructuras | 1d | 2025-08-10 | 2025-08-11 | 000487 | 57d | 0d | 5.6.6.5 | 1219 | Cronograma Gantt_7 | 2025-08-10 | 2025-10-06 | 2025-08-10 | 2025-08-11 | 2025-10-07 | 2025-08-11 | 488 | 488 |
| 000489 |  | Excavacion no clasificada de zanja | 2d | 2025-08-10 | 2025-08-12 | 000487 | 87d | 0d | 5.6.6.6 | 1220 | Cronograma Gantt_7 | 2025-08-10 | 2025-11-05 | 2025-08-10 | 2025-08-12 | 2025-11-07 | 2025-08-12 | 489 | 489 |
| 000490 |  | Relleno estructural | 4d | 2025-08-11 | 2025-08-15 | 000488 | 57d | 0d | 5.6.6.7 | 1221 | Cronograma Gantt_7 | 2025-08-11 | 2025-10-07 | 2025-08-11 | 2025-08-15 | 2025-10-11 | 2025-08-15 | 490 | 490 |
| 000485 |  | Desvío provisional con tubería | 1d | 2025-08-12 | 2025-08-13 | 000489 | 87d | 0d | 5.6.6.2 | 1216 | Cronograma Gantt_7 | 2025-08-12 | 2025-11-07 | 2025-08-12 | 2025-08-13 | 2025-11-08 | 2025-08-13 | 485 | 485 |
| 000502 |  | Cama de arena e=0.20m | 1d | 2025-08-12 | 2025-08-13 | 000489 | 90d | 0d | 5.6.6.19 | 1234 | Cronograma Gantt_7 | 2025-08-12 | 2025-11-10 | 2025-08-12 | 2025-08-13 | 2025-11-11 | 2025-08-13 | 502 | 502 |
| 000486 |  | Desvío provisional en tierras | 2d | 2025-08-13 | 2025-08-15 | 000485 | 87d | 0d | 5.6.6.3 | 1217 | Cronograma Gantt_7 | 2025-08-13 | 2025-11-08 | 2025-08-13 | 2025-08-15 | 2025-11-10 | 2025-08-15 | 486 | 486 |
| 000503 |  | Tubería HDPE Corrugada Ø=900mm (Suministro e instalación) | 1d | 2025-08-13 | 2025-08-14 | 000502 | 90d | 86d | 5.6.6.20 | 1235 | Cronograma Gantt_7 | 2025-08-13 | 2025-11-11 | 2025-08-13 | 2025-08-14 | 2025-11-12 | 2025-08-14 | 503 | 503 |
| 000491 |  | Suministro de roca (Alcantarillas) | 1d | 2025-08-15 | 2025-08-16 | 000486 | 87d | 0d | 5.6.6.8 | 1222 | Cronograma Gantt_7 | 2025-08-15 | 2025-11-10 | 2025-08-15 | 2025-08-16 | 2025-11-11 | 2025-08-16 | 491 | 491 |
| 000493 |  | Concreto de Nivelacion (f'c=100 kg/cm2) | 1d | 2025-08-15 | 2025-08-16 | 000490 | 57d | 0d | 5.6.6.10 | 1224 | Cronograma Gantt_7 | 2025-08-15 | 2025-10-11 | 2025-08-15 | 2025-08-16 | 2025-10-12 | 2025-08-16 | 493 | 493 |
| 000492 |  | Colocación de roca en uña (Alcantarillas) | 1d | 2025-08-16 | 2025-08-17 | 000491 | 87d | 83d | 5.6.6.9 | 1223 | Cronograma Gantt_7 | 2025-08-16 | 2025-11-11 | 2025-08-16 | 2025-08-17 | 2025-11-12 | 2025-08-17 | 492 | 492 |
| 000494 |  | Concreto Clase F (f'c=140 kg/cm2) | 2d | 2025-08-16 | 2025-08-18 | 000493 | 57d | 0d | 5.6.6.11 | 1225 | Cronograma Gantt_7 | 2025-08-16 | 2025-10-12 | 2025-08-16 | 2025-08-18 | 2025-10-14 | 2025-08-18 | 494 | 494 |
| 000499 |  | Acero de refuerzo f'y=4200kg/cm2 | 12d | 2025-08-18 | 2025-08-30 | 000494 | 57d | 0d | 5.6.6.16 | 1230 | Cronograma Gantt_7 | 2025-08-18 | 2025-10-14 | 2025-08-18 | 2025-08-30 | 2025-10-26 | 2025-08-30 | 499 | 499 |
| 000495 |  | Concreto Clase C (f'c=280 kg/cm2) Premezclado - Cimientos reforzados | 1d | 2025-08-30 | 2025-08-31 | 000499 | 57d | 0d | 5.6.6.12 | 1226 | Cronograma Gantt_7 | 2025-08-30 | 2025-10-26 | 2025-08-30 | 2025-08-31 | 2025-10-27 | 2025-08-31 | 495 | 495 |
| 000497 |  | Encofrado y Desencofrado Caravista | 4d | 2025-08-31 | 2025-09-04 | 000495 | 69d | 65d | 5.6.6.14 | 1228 | Cronograma Gantt_7 | 2025-08-31 | 2025-11-08 | 2025-08-31 | 2025-09-04 | 2025-11-12 | 2025-09-04 | 497 | 497 |
| 000498 |  | Encofrado y Desencofrado Cara Oculta | 7d | 2025-08-31 | 2025-09-07 | 000495 | 57d | 0d | 5.6.6.15 | 1229 | Cronograma Gantt_7 | 2025-08-31 | 2025-10-27 | 2025-08-31 | 2025-09-07 | 2025-11-03 | 2025-09-07 | 498 | 498 |
| 000496 |  | Concreto Clase C (f'c=280 kg/cm2) Premezclado - Muros de contencion | 2d | 2025-09-07 | 2025-09-09 | 000498 | 57d | 0d | 5.6.6.13 | 1227 | Cronograma Gantt_7 | 2025-09-07 | 2025-11-03 | 2025-09-07 | 2025-09-09 | 2025-11-05 | 2025-09-09 | 496 | 496 |
| 000500 |  | Emboquillado de piedra e=0.20m | 1d | 2025-09-09 | 2025-09-10 | 000496 | 63d | 59d | 5.6.6.17 | 1231 | Cronograma Gantt_7 | 2025-09-09 | 2025-11-11 | 2025-09-09 | 2025-09-10 | 2025-11-12 | 2025-09-10 | 500 | 500 |
| 000501 |  | Emboquillado de piedra e=0.30m | 2d | 2025-09-09 | 2025-09-11 | 000496 | 62d | 58d | 5.6.6.18 | 1232 | Cronograma Gantt_7 | 2025-09-09 | 2025-11-10 | 2025-09-09 | 2025-09-11 | 2025-11-12 | 2025-09-11 | 501 | 501 |
| 000504 |  | Sello en juntas | 1d | 2025-09-09 | 2025-09-10 | 000496 | 57d | 0d | 5.6.6.21 | 1238 | Cronograma Gantt_7 | 2025-09-09 | 2025-11-05 | 2025-09-09 | 2025-09-10 | 2025-11-06 | 2025-09-10 | 504 | 504 |
| 000507 |  | Suministro e Instalación de geotextil | 1d | 2025-09-09 | 2025-09-10 | 000496 | 63d | 59d | 5.6.6.24 | 1241 | Cronograma Gantt_7 | 2025-09-09 | 2025-11-11 | 2025-09-09 | 2025-09-10 | 2025-11-12 | 2025-09-10 | 507 | 507 |
| 000505 |  | Waterstop (anillos de estanqueidad) | 1d | 2025-09-10 | 2025-09-11 | 000504 | 57d | 0d | 5.6.6.22 | 1239 | Cronograma Gantt_7 | 2025-09-10 | 2025-11-06 | 2025-09-10 | 2025-09-11 | 2025-11-07 | 2025-09-11 | 505 | 505 |
| 000506 |  | Pintura bituminosa | 5d | 2025-09-11 | 2025-09-16 | 000505 | 57d | 53d | 5.6.6.23 | 1240 | Cronograma Gantt_7 | 2025-09-11 | 2025-11-07 | 2025-09-11 | 2025-09-16 | 2025-11-12 | 2025-09-16 | 506 | 506 |
